Schedule from MS Project, 2016-06-01 to 2021-03-31, A marks actual dates.

## Calendars

- Standard: Mon-Fri 08:00-12:00, 13:00-17:00; Sat-Sun off. Exceptions (off unless hours are given): 2017-12-25 to 2018-01-07 (Vancances hivers), 2018-01-13 08:00-12:00, 13:00-17:00.

## Resources

| Resource |
| --- |
| Aymeric BOUVARD |
| Jocelyn Tan |
| Alexandre SINTUREL |
| Romain ruffieux |
| Jean |
| EN-STI |
| EN-CV |
| EN-EA |
| SMB |
| HSE |
| TE-MSC |
| EN-HE |
| BE-BI |
| EN-EL |
| PR TL |
| EN/STI |
| Claudio Leopoldo Torregrosa Martin |
| EN/ACE/SU |
| EN/MME |
| Marc Timmins |
| Aurelio De Macedo |
| EN/EA/EC |
| Mark Butcher |
| Edouard Grenier-Boley |
| EN/CV |
| Alexandre Joel Broche |
| HSE/RP |
| SMB/SE |
| Eliseo Perez-Duenas |
| Michael Lazzaroni |
| EN/EL |
| Antony Newborough |
| Jean-Louis Grenard |
| Raul Fernandez Ortega |
| Alejandro Martinez Selles |

## Schedule

| ID | WBS | Task | Type | Duration | Start | Finish | Predecessors | Total slack | Free slack | Constraint | Text12 | Text2 |
| --- | --- | --- | --- | --- | --- | --- | --- | --- | --- | --- | --- | --- |
| 1 | 1 | **AEGIS relocation** |  | 525d | 2018-03-05 | 2020-03-06 |  | 278d |  |  | 2016 |  |
| 2 | 1.1 | ECR approved | milestone | 0d | 2018-03-05 | 2018-03-05 |  | 628d | 0d | start no earlier than 2018-03-05 |  |  |
| 3 | 1.2 | **Services relocation** |  | 30d | 2018-04-02 | 2018-05-11 |  | 628d |  |  |  |  |
| 4 | 1.2.1 | Electrical switchboards relocation |  | 3w | 2018-04-02 | 2018-04-20 | 2FS+4w | 628d | 0d |  |  | EN/EL |
| 5 | 1.2.2 | Fire hydrant relocation |  | 1w | 2018-04-23 | 2018-04-27 | 4 | 753d | 0d |  |  | EN/CV |
| 6 | 1.2.3 | Gas panel relocation |  | 1w | 2018-04-30 | 2018-05-04 | 5 | 753d | 0d |  |  | EN/EA |
| 7 | 1.2.4 | Access control central relocation |  | 1w | 2018-05-07 | 2018-05-11 | 6 | 753d |  |  |  | BE/ICS |
| 8 | 1.3 | **Infrastructure installation** |  | 370d | 2018-04-23 | 2019-09-20 |  | 278d | 0d |  |  |  |
| 9 | 1.3.1 | Exp area power sockets and lighting installation |  | 2w | 2018-04-23 | 2018-05-04 | 4 | 628d | 0d |  |  | EN/EL |
| 10 | 1.3.2 | Cooling water piping |  | 2w | 2018-05-07 | 2018-05-18 | 9 | 628d |  |  |  | EN/CV |
| 11 | 1.3.3 | ASACUSA laser equipment removal |  | 20w | 2018-11-12 | 2019-03-29 |  | 288d | 10d | start no earlier than 2018-11-12 |  |  |
| 12 | 1.3.4 | ASACUSA laser room EL disconnection |  | 1w | 2019-04-15 | 2019-04-19 | 11 | 278d | 0d | start no earlier than 2019-04-15 |  |  |
| 13 | 1.3.5 | ASACUSA laser room ventil ducts removal |  | 1w | 2019-04-22 | 2019-04-26 | 12 | 278d | 0d |  |  |  |
| 14 | 1.3.6 | ASACUSA laser room modif |  | 6w | 2019-04-29 | 2019-06-07 | 13 | 278d | 0d |  |  | SMB/SE |
| 15 | 1.3.7 | Platform over ASACUSA laser room installation |  | 4w | 2019-06-10 | 2019-07-05 | 14 | 278d | 0d |  |  |  |
| 16 | 1.3.8 | New Aegis laser room installation |  | 3w | 2019-07-08 | 2019-07-26 | 15 | 278d | 0d |  |  | SMB/HE |
| 17 | 1.3.9 | Concrete blocks installation |  | 1w | 2019-06-10 | 2019-06-14 | 14 | 348d |  |  |  | EN/HE |
| 18 | 1.3.10 | EL works for Aegis and ASACUSA laser rooms |  | 4w | 2019-07-29 | 2019-08-23 | 16 | 278d | 0d |  |  |  |
| 19 | 1.3.11 | CV works for Aegis and ASACUSA laser rooms |  | 4w | 2019-08-26 | 2019-09-20 | 18 | 278d |  |  |  |  |
| 20 | 1.4 | **LNE51 installation** |  | 79d | 2019-04-05 | 2019-07-24 |  | 440d |  |  |  |  |
| 21 | 1.4.1 | Transfer line tracing |  | 2d | 2019-04-05 | 2019-04-08 |  | 440d | 0d | start no earlier than 2019-04-05 |  | EN/ACE |
| 22 | 1.4.2 | Mechanical supports installation |  | 2w | 2019-04-09 | 2019-04-22 | 21 | 440d | 0d |  |  | EN/MME |
| 23 | 1.4.3 | Cable trays installation |  | 1w | 2019-04-23 | 2019-04-29 | 22 | 440d | 0d |  |  | EN/EL |
| 24 | 1.4.4 | HV and control cabling |  | 2w | 2019-04-30 | 2019-05-13 | 23 | 440d | 0d |  |  | EN/EL |
| 25 | 1.4.5 | Transfer lines elements installation |  | 2w | 2019-05-14 | 2019-05-27 | 24 | 440d | 0d |  |  | TE/VSC |
| 26 | 1.4.6 | Vacuum elements installation |  | 3w | 2019-05-28 | 2019-06-17 | 25 | 440d | 0d |  |  | TE/VSC |
| 27 | 1.4.7 | Position survey and alignment |  | 2d | 2019-06-18 | 2019-06-19 | 26 | 440d | 0d |  |  | EN/ACE |
| 28 | 1.4.8 | Vacuum connection + installation of vacuum equipment |  | 2w | 2019-06-20 | 2019-07-03 | 27 | 440d | 0d |  |  | TE/VSC |
| 29 | 1.4.9 | Bake-out operations |  | 3w | 2019-07-04 | 2019-07-24 | 28 | 440d |  |  |  | TE/VSC |
| 30 | 1.5 | Aegis experiment relocation |  | 12w | 2019-09-23 | 2019-12-13 | 8 | 278d | 0d |  |  | EP/UAD |
| 31 | 1.6 | Aegis experiment re-cabling |  | 12w | 2019-12-16 | 2020-03-06 | 30 | 278d |  |  |  | EP/UAD |

Notes:
- 2: Text10: 05/03/2018 - ECR approved
- 3: Text10: 11/05/2018 - Services relocation
- 4: Text10: 20/04/2018 - Electrical switchboards relocation
- 5: Text10: 27/04/2018 - Fire hydrant relocation
- 6: Text10: 04/05/2018 - Gas panel relocation
- 7: Text10: 11/05/2018 - Access control central relocation
- 8: Text10: 20/09/2019 - Infrastructure installation
- 9: Text10: 04/05/2018 - Exp area power sockets and lighting installation
- 10: Text10: 18/05/2018 - Cooling water piping
- 11: Text10: 12/04/2019 - ASACUSA laser equipment removal
- 12: Text10: 19/04/2019 - ASACUSA laser room EL disconnection
- 13: Text10: 26/04/2019 - ASACUSA laser room ventil ducts removal
- 14: Text10: 07/06/2019 - ASACUSA laser room modif
- 15: Text10: 05/07/2019 - Platform over ASACUSA laser room installation
- 16: Text10: 26/07/2019 - New Aegis laser room installation
- 17: Text10: 14/06/2019 - Concrete blocks installation
- 18: Text10: 23/08/2019 - EL works for Aegis and ASACUSA laser rooms
- 19: Text10: 20/09/2019 - CV works for Aegis and ASACUSA laser rooms
- 20: Text10: 24/07/2019 - LNE51 installation
- 21: Text10: 08/04/2019 - Transfer line tracing
- 22: Text10: 22/04/2019 - Mechanical supports installation
- 23: Text10: 29/04/2019 - Cable trays installation
- 24: Text10: 13/05/2019 - HV and control cabling
- 25: Text10: 27/05/2019 - Transfer lines elements installation
- 26: Text10: 17/06/2019 - Vacuum elements installation
- 27: Text10: 19/06/2019 - Position survey and alignment
- 28: Text10: 03/07/2019 - Vacuum connection + installation of vacuum equipment
- 29: Text10: 24/07/2019 - Bake-out operations
- 30: Text10: 13/12/2019 - Aegis experiment relocation
- 31: Text10: 20/03/2020 - Aegis experiment re-cabling

| ID | WBS | Task | Type | Duration | Start | Finish | Predecessors | Complete | Remaining | Baseline start | Baseline finish | Baseline duration | Baseline 1 start | Baseline 1 finish | Total slack | Free slack | Constraint | Resources | Work | Actual work | Text4 | Text5 | Text7 | Text2 |
| --- | --- | --- | --- | --- | --- | --- | --- | --- | --- | --- | --- | --- | --- | --- | --- | --- | --- | --- | --- | --- | --- | --- | --- | --- |
| 32 | 2 | **LS2 AD Target** |  | 1252d? | 2016-06-01 A | 2021-03-31 |  | 22% | 978.23d? |  |  |  |  |  | 0d |  |  |  | 141190h | 18417.3h |  |  |  |  |
| 33 | 2.1 | **WP1: Target Area Coordination** |  | 679d | 2016-11-09 | 2019-06-28 |  |  |  | 2016-11-09 | 2019-01-17 | 571.88d | 2016-11-09 | 2019-06-28 | 458d |  |  | EN/STI | 6120h |  | Other | WP1 | 1537538 |  |
| 34 | 2.1.1 | waste planning | milestone | 0d | 2016-11-09 | 2016-11-09 |  |  |  | 2016-11-09 | 2016-11-09 | 0d | 2016-11-09 | 2016-11-09 | 1137d |  | start no earlier than 2016-11-09 | EN/STI |  |  | Other | WP1 |  | 853 |
| 35 | 2.1.2 | removal of target and horn system |  | 86d | 2019-03-01 | 2019-06-28 |  |  |  | 2019-01-03 | 2019-01-17 | 2w | 2019-03-01 | 2019-06-28 | 301d | 0d | start no earlier than 2019-03-01 | EN/STI | 688h |  | Other | WP1 |  | 853 |
| 36 | 2.2 | **WP2: Target** |  | 1115d | 2016-11-09 | 2021-03-01 |  |  |  | 2016-11-09 | 2019-01-21 | 574d | 2016-11-09 | 2021-03-01 | 22d |  |  | EN/STI | 13320h |  | R&D | WP2 |  |  |
| 37 | 2.2.1 | design |  | 6mo | 2016-11-09 | 2017-04-25 |  |  |  | 2016-11-09 | 2017-04-25 | 6mo | 2016-11-09 | 2017-04-25 | 857d | 0d | start no earlier than 2016-11-09 | Claudio Leopoldo Torregrosa Martin | 960h |  | R&D - Design | WP2 |  |  |
| 38 | 2.2.2 | procurement |  | 3mo | 2017-04-26 | 2017-07-18 | 37 |  |  | 2017-04-26 | 2017-07-18 | 3mo | 2017-04-26 | 2017-07-18 | 857d | 0d |  | Claudio Leopoldo Torregrosa Martin | 480h |  | R&D - Procurement | WP2 |  |  |
| 39 | 2.2.3 | Target production |  | 4mo | 2017-07-19 | 2017-11-07 | 38 |  |  | 2017-07-19 | 2017-11-07 | 4mo | 2017-07-19 | 2017-11-07 | 857d | 0d |  | Claudio Leopoldo Torregrosa Martin; EN/ACE/SU; EN/MME | 1920h |  | R&D - Manufacturing | WP2 |  |  |
| 40 | 2.2.4 | tests |  | 1mo | 2017-11-08 | 2017-12-05 | 39 |  |  | 2017-11-08 | 2017-12-05 | 1mo | 2017-11-08 | 2017-12-05 | 857d | 0d |  | EN/STI | 160h |  | R&D - Tests | WP2 |  |  |
| 41 | 2.2.5 | tests completed | milestone | 0d | 2017-12-05 | 2017-12-05 | 37, 38, 39, 40 |  |  | 2017-12-06 | 2017-12-06 | 0d | 2017-12-06 | 2017-12-06 | 857d |  |  | EN/STI |  |  | R&D - Tests | WP2 |  |  |
| 42 | 2.2.6 | Installation target |  | 2d | 2020-09-01 | 2020-09-02 | 55 |  |  | 2020-02-03 | 2020-02-04 | 2d | 2020-09-01 | 2020-09-02 | 140d | 0d |  | EN/STI | 16h |  | R&D - Installation | WP2 |  | 853 |
| 43 | 2.2.7 | Local tests |  | 108d | 2020-10-01 | 2021-03-01 |  |  |  |  |  |  | 2020-10-01 | 2021-03-01 | 22d |  | start no earlier than 2020-10-01 | EN/STI | 864h |  | R&D - Tests | WP2 |  | 853 |
| 44 | 2.3 | **WP3: Magnet Horn** |  | 1112d? | 2016-06-01 A | 2020-09-16 |  | 68% | 355.71d? | 2016-06-01 | 2020-02-28 | 978d? | 2016-06-01 | 2020-09-02 | 140d |  |  | EN/STI; EN/MME | 24215.2h | 10275.3h | R&D | WP3 |  |  |
| 45 | 2.3.1 | design |  | 5.9mo | 2016-06-01 A | 2016-11-11 |  | 95% | 0.29mo | 2016-06-01 | 2016-11-11 | 5.9mo | 2016-06-01 | 2016-11-11 | 1134d |  | finish no earlier than 2016-11-11 | EN/STI | 944h | 896.8h | R&D - Design | WP3 | 1688119 |  |
| 46 | 2.3.2 | design test support |  | 1mo | 2016-11-14 A | 2016-12-09 A | 45 | 100% |  | 2016-11-14 | 2016-12-09 | 1mo | 2016-11-14 | 2016-12-09 |  |  |  | Marc Timmins | 160h | 160h | R&D - Design | WP3 |  |  |
| 47 | 2.3.3 | build test support |  | 5.3mo | 2017-04-10 A | 2017-09-04 A | 46 | 100% |  | 2017-04-10 | 2017-09-03 | 5.3mo | 2017-04-10 | 2017-09-03 |  |  |  | Marc Timmins | 848h | 848h | R&D - Manufacturing | WP3 |  |  |
| 48 | 2.3.4 | production horn 1 |  | 2mo | 2017-05-29 A | 2017-07-21 A | 47 | 100% |  | 2017-05-29 | 2017-07-21 | 2mo | 2017-05-29 | 2017-07-21 |  |  |  | Aurelio De Macedo; EN/ACE/SU; EN/EA/EC | 320h | 320h | R&D - Manufacturing | WP3 |  |  |
| 49 | 2.3.5 | installation of test horn in 195 |  | 14d | 2017-09-18 A | 2017-10-05 A |  | 100% |  | 2017-09-17 | 2017-10-05 | 3w | 2017-09-17 | 2017-10-05 |  |  | finish no earlier than 2017-10-05 | Claudio Leopoldo Torregrosa Martin; Aurelio De Macedo; Mark Butcher | 336h | 336h | R&D - Installation | WP3 |  | 195 |
| 50 | 2.3.6 | tests in 195 |  | 9.6mo? | 2017-10-06 A | 2018-07-13 | 46, 48, 49 | 26% | 7.1mo? | 2017-10-06 | 2018-07-12 | 10mo? | 2017-10-06 | 2018-07-12 | 708d |  | finish no earlier than 2018-07-13 | Claudio Leopoldo Torregrosa Martin; Aurelio De Macedo; Mark Butcher | 4608h | 1200h | R&D - Tests | WP3 |  | 195 |
| 51 | 2.3.7 | production horn 2.. |  | 1d? | 2018-07-13 | 2018-07-13 |  |  |  | 2016-06-01 | 2016-06-01 | 1d? | 2016-06-01 | 2016-06-01 | 708d |  | start no earlier than 2018-07-13 | EN/STI | 8h |  | R&D - Manufacturing | WP3 |  |  |
| 52 | 2.3.8 | Horn ready to instal | milestone | 0d | 2018-02-05 | 2018-02-05 |  |  |  | 2018-02-05 | 2018-02-05 | 0d | 2018-02-05 | 2018-02-05 | 0d |  | must start on 2018-02-05 | EN/STI |  |  | R&D - Installation | WP3 |  |  |
| 53 | 2.3.9 | Horn installation |  | 2d | 2020-09-01 | 2020-09-02 | 52, 55 |  |  | 2020-02-03 | 2020-02-04 | 2d | 2020-09-01 | 2020-09-02 | 140d | 0d |  | EN/STI | 16h |  | R&D - Installation | WP3 |  | 853 |
| 54 | 2.3.10 | Horn comissioning |  | 2w | 2020-09-03 | 2020-09-16 | 42, 53 |  |  | 2020-02-17 | 2020-02-28 | 2w | 2020-02-17 | 2020-02-28 | 140d |  |  | EN/STI | 80h |  | R&D - Tests | WP3 |  | 853 |
| 55 | 2.4 | **WP4: Trolley system (support frames and trolley)** |  | 862d | 2017-05-01 A | 2020-09-01 |  | 7% | 799.61d | 2017-05-01 | 2020-01-31 | 720d | 2017-05-01 | 2020-09-01 | 140d | 0d |  | EN/ACE/SU; EN/MME; EN/STI | 47271.3h | 3441.8h | R&D | WP4 |  |  |
| 56 | 2.4.1 | **building 195 test facility** |  | 160d | 2017-05-01 A | 2017-12-08 |  | 36% | 101.82d | 2017-05-01 | 2017-12-01 | 155d | 2017-05-01 | 2017-12-01 | 842d |  |  | EN/ACE/SU; EN/MME; EN/STI | 5367.27h | 1876.37h | R&D | WP4 |  | 195 |
| 57 | 2.4.1.1 | busbar b.195 clamp design |  | 120d | 2017-05-01 A | 2017-10-13 |  | 50% | 60d | 2017-05-01 | 2017-10-15 | 121d | 2017-05-01 | 2017-10-15 | 842d | 0d | start no earlier than 2017-05-01 | Marc Timmins; Edouard Grenier-Boley | 960h | 480h | R&D - Design | WP4 |  |  |
| 58 | 2.4.1.2 | clamp b.195 manufacturing |  | 6w | 2017-10-16 | 2017-11-24 | 57 |  |  | 2017-10-16 | 2017-11-24 | 6w | 2017-10-16 | 2017-11-24 | 842d | 0d |  | EN/STI; EN/MME | 480h |  | R&D - Manufacturing | WP4 |  |  |
| 59 | 2.4.1.3 | clamp installation in 195 |  | 1w | 2017-11-27 | 2017-12-01 | 58 |  |  | 2017-11-27 | 2017-12-01 | 1w | 2017-11-27 | 2017-12-01 | 847d |  |  | EN/STI; EN/MME | 80h |  | R&D - Installation | WP4 |  | 195 |
| 60 | 2.4.1.4 | installation ctrl sys for 195 clamp test |  | 2w | 2017-11-27 | 2017-12-08 | 58 |  |  | 2017-05-01 | 2017-05-12 | 2w | 2017-05-01 | 2017-05-12 | 842d |  |  | Mark Butcher | 80h |  | R&D - Installation | WP4 |  | 195 |

Notes:
- 33: https://indico.cern.ch/event/662254/contributions/2704333/attachments/1517601/2369133/Dismantling__Decontamination_AD-T.pdf
- 36: 25.10.17 : end moved from 4/2/20 to 1/3/21 due to new task ''Local tests''

| ID | WBS | Task | Type | Duration | Start | Finish | Predecessors | Baseline start | Baseline finish | Baseline duration | Baseline 1 start | Baseline 1 finish | Total slack | Free slack | Constraint | Resources | Work | Text2 | Text4 | Text5 | Text7 |
| --- | --- | --- | --- | --- | --- | --- | --- | --- | --- | --- | --- | --- | --- | --- | --- | --- | --- | --- | --- | --- | --- |
| 61 | 2.4.2 | **building 232 test facility** |  | 391d | 2017-09-29 | 2019-04-11 |  | 2017-09-29 | 2019-04-11 | 400d | 2017-09-29 | 2019-04-11 | 143d |  |  | EN/ACE/SU; EN/MME; EN/STI | 18976h | 232 | R&D | WP4 |  |
| 62 | 2.4.2.1 | design of 232 trolley prototype |  | 7.55mo | 2017-09-29 | 2018-05-10 |  | 2017-09-29 | 2018-05-10 | 8mo | 2017-09-29 | 2018-05-10 | 382d | 0d | finish no earlier than 2018-05-10 | Claudio Leopoldo Torregrosa Martin; Edouard Grenier-Boley; Marc Timmins | 3624h |  | R&D - Design | WP4 | 1707362 |
| 63 | 2.4.2.2 | Motors defined | milestone | 0d | 2018-05-01 | 2018-05-01 |  |  |  |  | 2018-05-01 | 2018-05-01 | 0d |  | must start on 2018-05-01 | Claudio Leopoldo Torregrosa Martin; Edouard Grenier-Boley; Marc Timmins |  |  | R&D - Design | WP4 |  |
| 64 | 2.4.2.3 | production of the 232 prototype |  | 5mo | 2018-05-11 | 2018-09-27 | 62 | 2018-05-11 | 2018-09-27 | 5mo | 2018-05-11 | 2018-09-27 | 382d | 0d |  | EN/STI; EN/MME | 1600h |  | R&D - Manufacturing | WP4 |  |
| 65 | 2.4.2.4 | Installation in b. 232 |  | 3mo | 2018-09-28 | 2018-12-20 | 64 | 2018-09-28 | 2018-12-20 | 3mo | 2018-09-28 | 2018-12-20 | 382d | 0d |  | EN/STI; EN/MME | 960h | 232 | R&D - Installation | WP4 |  |
| 66 | 2.4.2.5 | trolley ctrl sys |  | 133d | 2018-05-01 | 2018-11-01 | 63 | 2018-12-21 | 2018-12-21 | 0w | 2018-05-01 | 2018-11-01 | 617d |  |  | EN/STI; EN/MME | 2128h |  | R&D - Design | WP4 |  |
| 67 | 2.4.2.6 | Trolley Prototype ready (installed and operating) in 232 | milestone | 0d | 2018-11-01 | 2018-11-01 |  |  |  |  | 2018-11-01 | 2018-11-01 | 0d |  | must start on 2018-11-01 | EN/STI; EN/MME |  | 232 | R&D | WP4 |  |
| 68 | 2.4.2.7 | tests in 232 |  | 1mo | 2018-12-21 | 2019-01-17 | 65 | 2018-12-21 | 2019-01-17 | 1mo | 2018-12-21 | 2019-01-17 | 382d | 0d |  | EN/STI; EN/MME | 320h | 232 | R&D - Tests | WP4 |  |
| 69 | 2.4.2.8 | second design iteration and new 232 test |  | 3mo | 2019-01-18 | 2019-04-11 | 68 | 2019-01-18 | 2019-04-11 | 3mo | 2019-01-18 | 2019-04-11 | 382d | 0d |  | EN/STI; EN/MME | 960h | 232 | R&D - Tests | WP4 |  |
| 70 | 2.4.3 | production of trolley and support frames |  | 6mo | 2019-04-12 | 2019-09-26 | 69 | 2019-04-12 | 2019-09-26 | 6mo | 2019-04-12 | 2019-09-26 | 382d | 68d | finish no earlier than 2018-01-31 | EN/STI; EN/MME | 1920h |  | R&D - Manufacturing | WP4 |  |
| 71 | 2.4.4 | Documentation & Safety file ready | milestone | 0d | 2019-07-01 | 2019-07-01 |  |  |  |  | 2019-07-01 | 2019-07-01 | 0d |  | must start on 2019-07-01 | EN/STI; EN/MME |  |  | R&D | WP4 |  |
| 72 | 2.4.5 | Final trolleys & supports ready to instal | milestone | 0d | 2020-01-01 | 2020-01-01 | 62, 70 | 2019-09-26 | 2019-09-26 | 0d | 2020-01-01 | 2020-01-01 | 314d |  | start no earlier than 2020-01-01 | EN/STI; EN/MME |  | 853 | R&D - Installation | WP4 |  |
| 73 | 2.4.6 | strip down existing trolley system |  | 1w | 2019-03-01 | 2019-03-07 |  | 2018-12-10 | 2018-12-14 | 1w | 2019-01-03 | 2019-01-10 | 382d | 81d | start no earlier than 2019-03-01 | EN/STI; EN/MME | 80h | 853 | R&D - Dismantling | WP4 |  |
| 74 | 2.4.7 | Installation of trolleys |  | 3w | 2020-03-23 | 2020-04-10 | 112 | 2020-01-13 | 2020-01-31 | 3w | 2020-03-23 | 2020-04-10 | 241d |  | finish no earlier than 2020-01-31 | EN/STI; EN/MME | 240h | 853 | R&D - Installation | WP4 |  |
| 75 | 2.4.8 | Control for trolley in target area | milestone | 0d | 2020-09-01 | 2020-09-01 |  |  |  |  | 2020-09-01 | 2020-09-01 | 0d |  | must start on 2020-09-01 | EN/STI; EN/MME |  | 853 | R&D - Installation | WP4 |  |
| 76 | 2.5 | **WP5: Ventilation System replacement** |  | 1137d | 2016-11-09 | 2021-03-31 |  | 2016-11-09 | 2021-04-01 | 1147d | 2016-11-09 | 2021-04-01 | 0d |  |  | EN/CV | 9616h | 196 | 853&196 Refurbishment |  |  |
| 77 | 2.5.1 | design |  | 1mo | 2016-11-09 | 2016-12-06 |  | 2016-11-09 | 2016-12-06 | 1mo | 2016-11-09 | 2016-12-06 | 1072d | 0d | start no earlier than 2016-11-09 | Alexandre Joel Broche | 160h | 853,196 | 853&196 Refurbishment |  |  |
| 78 | 2.5.2 | procurement |  | 1mo | 2016-12-07 | 2017-01-03 | 77 | 2016-12-07 | 2017-01-03 | 1mo | 2016-12-07 | 2017-01-03 | 1072d | 644d |  | Alexandre Joel Broche | 160h | 853,196 | 853&196 Refurbishment - Procurement |  |  |
| 79 | 2.5.3 | IT for CV installation | milestone | 0d | 2018-06-01 | 2018-06-01 |  |  |  |  | 2018-06-01 | 2018-06-01 | 0d |  | must start on 2018-06-01 | Alexandre Joel Broche |  | 853,196 | 853&196 Refurbishment - Procurement |  |  |
| 80 | 2.5.4 | removal of old system |  | 1w | 2019-07-08 | 2019-07-12 | 78, 84, 85 | 2019-01-24 | 2019-01-31 | 1w | 2019-07-08 | 2019-07-12 | 428d |  |  | Alexandre Joel Broche | 40h | 853,196 | 853&196 Refurbishment - Dismantling |  |  |
| 81 | 2.5.5 | Installation |  | 1mo | 2021-03-04 | 2021-03-31 | 80 | 2021-03-05 | 2021-04-01 | 1mo | 2021-03-05 | 2021-04-01 | 0d |  | start no earlier than 2021-03-04 | Alexandre Joel Broche | 160h | 853,196 | 853&196 Refurbishment - Installation |  |  |
| 82 | 2.6 | **WP6: decontamination target area** |  | 640d | 2017-05-08 | 2019-10-31 |  | 2017-05-08 | 2019-01-24 | 448.88d | 2017-05-08 | 2019-10-31 | 261d | 0d |  | EN/EA/EC; EN/STI; HSE/RP | 17704h | 853 | Other |  |  |
| 83 | 2.6.1 | issue specification |  | 1w | 2017-05-08 | 2017-05-12 |  | 2017-05-08 | 2017-05-12 | 1w | 2017-05-08 | 2017-05-12 | 787d | 0d | start no earlier than 2017-05-08 | EN/EA/EC; EN/STI; HSE/RP | 120h |  | Other |  |  |
| 84 | 2.6.2 | procurement |  | 3mo | 2017-05-15 | 2017-08-04 | 83 | 2017-05-15 | 2017-08-04 | 3mo | 2017-05-15 | 2017-08-04 | 787d | 486d |  | EN/EA/EC; EN/STI; HSE/RP | 1440h |  | Other |  |  |
| 85 | 2.6.3 | decontamination |  | 1w | 2019-07-01 | 2019-07-05 | 35, 73, 84, 110 | 2019-01-17 | 2019-01-24 | 1w | 2019-07-01 | 2019-07-05 | 301d | 0d |  | EN/EA/EC; HSE/RP | 80h | 853 | Other |  |  |
| 86 | 2.6.4 | Area clean and ready for installation work |  | 44d | 2019-09-02 | 2019-10-31 | 85 | 2019-01-24 | 2019-01-24 | 0d | 2019-09-01 | 2019-10-31 | 261d |  | start no earlier than 2019-09-02 | EN/EA/EC; HSE/RP | 704h | 853 | Other |  |  |

Notes:
- 73: 25.01.17: Changes from 10/12/18 to 3/1/19 as target area access occurs here
- 76: https://indico.cern.ch/event/662254/contributions/2704332/attachments/1517792/2369565/AD_Target_4sept_kickoff_20170901.pdf
- 81: 1 mon confirmed meeting 3.8.17
- 82: https://indico.cern.ch/event/662254/contributions/2704333/attachments/1517601/2369133/Dismantling__Decontamination_AD-T.pdf

| ID | WBS | Task | Type | Duration | Start | Finish | Predecessors | Complete | Remaining | Baseline start | Baseline finish | Baseline duration | Baseline 1 start | Baseline 1 finish | Total slack | Free slack | Constraint | Resources | Work | Actual work | Text2 | Text4 |
| --- | --- | --- | --- | --- | --- | --- | --- | --- | --- | --- | --- | --- | --- | --- | --- | --- | --- | --- | --- | --- | --- | --- |
| 87 | 2.7 | **WP7: surface building refurbishement** |  | 994d? | 2016-10-27 A | 2020-08-31 |  | 33% | 668.47d? | 2016-10-27 | 2020-06-03 | 940d? | 2016-10-27 | 2020-08-31 | 152d |  |  | SMB/SE | 14336h | 4700.28h | 196 | 196 Refurbishment |
| 88 | 2.7.1 | DO-30343 Design |  | 20w | 2016-10-27 A | 2017-03-15 A |  | 100% |  | 2016-10-27 | 2017-03-15 | 20w | 2016-10-27 | 2017-03-15 |  |  | finish no earlier than 2017-03-15 | Eliseo Perez-Duenas | 800h | 800h |  | 196 Refurbishment |
| 89 | 2.7.2 | Design Studies |  | 7mo | 2017-03-20 A | 2017-09-29 A | 88 | 100% |  | 2017-03-20 | 2017-09-29 | 7mo | 2017-03-20 | 2017-09-29 |  |  | finish no earlier than 2017-09-29 | Eliseo Perez-Duenas | 1120h | 1120h |  | 196 Refurbishment |
| 90 | 2.7.3 | Checked by CV and pre-study done |  | 35d | 2017-12-01 A | 2018-01-31 | 89 | 63% | 13d |  |  |  |  |  | 825d |  | finish no earlier than 2018-01-31 | EN/CV | 280h | 176h |  |  |
| 91 | 2.7.4 | Tender done | milestone | 0d | 2018-03-30 | 2018-03-30 |  |  |  |  |  |  |  |  | 0d |  | must start on 2018-03-30 |  |  |  |  |  |
| 92 | 2.7.5 | Road enlargement |  | 21d | 2018-04-02 | 2018-04-30 |  |  |  |  |  |  |  |  | 0d |  | must start on 2018-04-02 |  |  |  | 196 | 196 Refurbishment |
| 93 | 2.7.6 | IT building Contractor | milestone | 0mo | 2018-07-02 | 2018-07-02 | 89 |  |  | 2017-10-02 | 2018-07-02 | 9.8mo | 2018-07-02 | 2018-07-02 | 262d | 63d | start no earlier than 2018-07-02 | Eliseo Perez-Duenas |  |  |  | 196 Refurbishment - Procurement |
| 94 | 2.7.7 | September 2018 FC | milestone | 0d | 2018-09-27 | 2018-09-27 | 93 |  |  | 2018-09-27 | 2018-09-27 | 0d | 2018-09-27 | 2018-09-27 | 199d | 12d | start no earlier than 2018-09-27 | SMB/SE |  |  |  | 196 Refurbishment - Procurement |
| 95 | 2.7.8 | Detailed design done | milestone | 0d | 2018-10-15 | 2018-10-15 | 94 |  |  |  |  |  |  |  | 187d | 35d | start no earlier than 2018-10-15 | SMB/SE |  |  |  |  |
| 96 | 2.7.9 | Preparation CE works/stripdown equipment |  | 44d | 2018-12-03 | 2019-01-31 | 95 |  |  | 2018-10-22 | 2018-12-20 | 44d | 2018-12-01 | 2019-01-31 | 152d | 0d | start no earlier than 2018-12-01 | Eliseo Perez-Duenas | 352h |  | 196 | 196 Refurbishment - Dismantling |
| 97 | 2.7.10 | Demolition of existing 196 |  | 4w | 2019-02-01 | 2019-02-28 | 96 |  |  | 2019-01-31 | 2019-02-27 | 4w | 2019-01-31 | 2019-02-27 | 152d | 0d |  | Michael Lazzaroni; Eliseo Perez-Duenas | 320h |  | 196 | 196 Refurbishment - Dismantling |
| 98 | 2.7.11 | Construction Building 196 |  | 199d | 2019-03-01 | 2019-12-04 | 97, 104 |  |  | 2019-02-28 | 2019-12-04 | 200d | 2019-03-01 | 2019-12-04 | 152d | 0d | finish no earlier than 2019-12-04 | Eliseo Perez-Duenas | 1592h |  | 196 | 196 Refurbishment - Installation/Construction |
| 99 | 2.7.12 | Electricity |  | 10w | 2019-12-05 | 2020-08-31 | 98 |  |  | 2019-12-05 | 2019-12-18 | 2w | 2019-12-05 | 2020-08-31 | 152d | 0d |  | EN/EL | 400h |  | 196 | 196 Refurbishment - Installation/Construction |
| 100 | 2.7.13 | Water |  | 1d? | 2016-11-09 | 2016-11-09 |  |  |  | 2016-11-09 | 2016-11-09 | 1d? | 2016-11-09 | 2016-11-09 | 1136d |  | start no earlier than 2016-11-09 |  |  |  | 196 | 196 Refurbishment - Installation/Construction |
| 101 | 2.7.14 | Install CV in 196 |  | 190d | 2019-11-11 | 2020-07-31 | 99SS-18d |  |  | 2019-12-19 | 2020-06-03 | 6mo | 2019-11-09 | 2020-07-31 | 173d |  |  | EN/CV | 1520h |  | 196 | 196 Refurbishment - Installation/Construction |
| 102 | 2.8 | **WP8: safety systems and secondary services** |  | 2d | 2016-11-09 | 2016-11-10 |  |  |  | 2016-11-09 | 2016-11-10 | 2d | 2016-11-09 | 2016-11-10 | 743d |  |  |  | 32h |  | 196 | 196 Refurbishment |
| 103 | 2.8.1 | renovate infiltration water pump control |  | 1d | 2016-11-09 | 2016-11-09 |  |  |  | 2016-11-09 | 2016-11-09 | 1d | 2016-11-09 | 2016-11-09 | 1136d |  | start no earlier than 2016-11-09 | Alexandre Joel Broche | 8h |  | 196 | 196 Refurbishment - Installation/Construction |
| 104 | 2.8.2 | secure inf. Water pump power supply during 196 renov |  | 2d | 2016-11-09 | 2016-11-10 |  |  |  | 2016-11-09 | 2016-11-10 | 2d | 2016-11-09 | 2016-11-10 | 743d | 591d | start no earlier than 2016-11-09 | Alexandre Joel Broche | 16h |  | 196 | 196 Refurbishment - Installation/Construction |
| 105 | 2.8.3 | integration of target water spill recovery |  | 1d | 2016-11-09 | 2016-11-09 |  |  |  | 2016-11-09 | 2016-11-09 | 1d | 2016-11-09 | 2016-11-09 | 1136d |  | start no earlier than 2016-11-09 | Alexandre Joel Broche | 8h |  | 196 | 196 Refurbishment - Installation/Construction |
| 106 | 2.9 | **WP9: Magnets** |  | 870d? | 2016-11-09 | 2020-03-23 |  |  |  | 2019-01-08 | 2019-02-27 | 36d? | 2019-03-06 | 2020-03-20 | 267d |  |  | Antony Newborough | 6960h |  |  | 853 Refurbishment |
| 107 | 2.9.1 | Construction of new magents |  | 1d? | 2016-11-09 | 2016-11-09 |  |  |  | 2019-01-08 | 2019-01-09 | 1d? | 2019-03-06 | 2019-03-06 | 1136d |  | start no earlier than 2016-11-09 |  |  |  |  | 853 Refurbishment |
| 108 | 2.9.2 | **Magnet removal** |  | 6d? | 2019-03-06 | 2019-03-13 | 120 |  |  | 2019-01-08 | 2019-01-16 | 6d? | 2019-03-06 | 2019-03-13 | 187d | 0d |  |  |  |  | 853 | 853 Refurbishment - Dismantling |
| 109 | 2.9.2.1 | magnets removal upstream target |  | 1d? | 2019-03-06 | 2019-03-06 |  |  |  | 2019-01-08 | 2019-01-09 | 1d? | 2019-03-06 | 2019-03-06 | 187d | 0d | start no earlier than 2019-03-06 |  |  |  | 853 | 853 Refurbishment - Dismantling |
| 110 | 2.9.2.2 | magnets removal downstream securing prealignement |  | 4d | 2019-03-07 | 2019-03-12 | 109 |  |  | 2019-01-09 | 2019-01-15 | 4d | 2019-03-07 | 2019-03-12 | 187d | 0d |  |  |  |  | 853 | 853 Refurbishment - Dismantling |
| 111 | 2.9.2.3 | Removal of supports upstream target |  | 1d? | 2019-03-13 | 2019-03-13 | 110 |  |  | 2019-01-15 | 2019-01-16 | 1d? | 2019-03-13 | 2019-03-13 | 187d |  |  |  |  |  | 853 | 853 Refurbishment - Dismantling |

Notes:
- 89: Preliminary geometry study done / "permise de construction" is ready
- 90: -should say the required modifications / -should check space for electronic racks
- 91: Will have one more month of internal checking
- 92: -on both left and right side / -budget has to be checked / -coordination with works in other buildings is required / -must finish before summer 2018 because of b.232 mock-up / (if budget, maybe 232 works for the thermal isolating the building)
- 95: -don t forget the water draining system

| ID | WBS | Task | Type | Duration | Start | Finish | Predecessors | Baseline start | Baseline finish | Baseline duration | Baseline 1 start | Baseline 1 finish | Total slack | Free slack | Constraint | Resources | Work | Text2 | Text4 |
| --- | --- | --- | --- | --- | --- | --- | --- | --- | --- | --- | --- | --- | --- | --- | --- | --- | --- | --- | --- |
| 112 | 2.9.3 | **Magnet installation** |  | 15d | 2020-03-02 | 2020-03-20 | 123 | 2019-02-06 | 2019-02-27 | 15d | 2020-03-02 | 2020-03-20 | 241d | 0d |  |  |  | 853 | 853 Refurbishment - Installation |
| 113 | 2.9.3.1 | Installation of magnet supports |  | 3d | 2020-03-02 | 2020-03-04 |  | 2019-02-06 | 2019-02-11 | 3d | 2020-03-02 | 2020-03-04 | 241d | 0d |  |  |  | 853 | 853 Refurbishment - Installation |
| 114 | 2.9.3.2 | Installation of electro magnets |  | 1w | 2020-03-05 | 2020-03-11 | 113 | 2019-02-11 | 2019-02-18 | 1w | 2020-03-05 | 2020-03-11 | 241d | 0d |  |  |  | 853 | 853 Refurbishment - Installation |
| 115 | 2.9.3.3 | Installation of permanent magnets |  | 1w | 2020-03-12 | 2020-03-18 | 114 | 2019-02-18 | 2019-02-25 | 1w | 2020-03-12 | 2020-03-18 | 241d | 0d |  |  |  | 853 | 853 Refurbishment - Installation |
| 116 | 2.9.3.4 | hydraulic and electric connection |  | 2d | 2020-03-19 | 2020-03-20 | 115 | 2019-02-25 | 2019-02-27 | 2d | 2020-03-19 | 2020-03-20 | 241d |  |  |  |  | 853 | 853 Refurbishment - Installation |
| 117 | 2.9.4 | Comissioning |  | 1d? | 2020-03-23 | 2020-03-23 | 112 | 2019-01-08 | 2019-01-09 | 1d? | 2019-03-06 | 2019-03-06 | 267d |  |  |  |  | 853 | 853 Refurbishment |
| 118 | 2.10 | WP10: Handling equipment target area |  | 1d? | 2016-11-09 | 2016-11-09 |  | 2016-11-09 | 2016-11-09 | 1d? | 2016-11-09 | 2016-11-09 | 1136d |  | start no earlier than 2016-11-09 |  |  | 853 | 853 Refurbishment - Dismantling |
| 119 | 2.11 | **WP11: Beam Instrumentation** |  | 391d? | 2019-03-05 | 2020-09-01 |  | 2016-11-09 | 2019-01-08 | 564.88d? | 2019-03-05 | 2020-09-01 | 151d |  |  |  |  | 853 | R&D |
| 120 | 2.11.1 | removal of all BI equipment |  | 1d? | 2019-03-05 | 2019-03-05 | 124 | 2019-01-07 | 2019-01-08 | 1d? | 2019-03-05 | 2019-03-05 | 187d | 0d | start no earlier than 2019-03-05 |  |  | 853 | R&D - Dismantling |
| 121 | 2.11.2 | Installation of beam instrumentation |  | 132d | 2020-03-02 | 2020-09-01 |  | 2016-11-09 | 2016-11-09 | 1d? | 2020-03-02 | 2020-09-01 | 151d |  | start no earlier than 2020-03-02 |  |  | 853 | R&D - Installation |
| 122 | 2.12 | **WP12: Electrical Infrastructure** |  | 854d | 2016-11-09 | 2020-02-28 |  | 2016-11-09 | 2019-02-06 | 585.88d | 2016-11-09 | 2020-03-01 | 283d |  |  |  |  |  | 853 Refurbishment |
| 123 | 2.12.1 | **Target area** |  | 261d | 2019-03-01 | 2020-02-28 |  | 2019-01-03 | 2019-02-06 | 24d | 2019-03-01 | 2020-03-01 | 187d | 0d |  |  |  |  | 853 Refurbishment |
| 124 | 2.12.1.1 | consignation |  | 2d | 2019-03-01 | 2019-03-04 |  | 2019-01-03 | 2019-01-07 | 2d | 2019-03-01 | 2019-03-04 | 187d | 0d | start no earlier than 2019-03-01 |  |  |  | 853 Refurbishment |
| 125 | 2.12.1.2 | removal of cables |  | 3d | 2019-03-18 | 2019-03-20 | 134 | 2019-01-18 | 2019-01-23 | 3d | 2019-03-18 | 2019-03-20 | 488d |  |  |  |  | 853 | 853 Refurbishment - Dismantling |
| 126 | 2.12.1.3 | Pulling new cables |  | 3d | 2019-12-02 | 2019-12-04 | 132 | 2019-01-25 | 2019-01-30 | 3d | 2019-12-02 | 2019-12-04 | 241d | 0d |  |  |  | 853 | 853 Refurbishment - Dismantling |
| 127 | 2.12.1.4 | Installation of lighting and sockets |  | 1w | 2019-12-05 | 2019-12-11 | 126 | 2019-01-30 | 2019-02-06 | 1w | 2019-12-05 | 2019-12-11 | 241d | 0d |  |  |  | 853 | 853 Refurbishment - Installation |
| 128 | 2.12.1.5 | cabling |  | 43d | 2020-01-01 | 2020-02-28 | 127FS+14d |  |  |  | 2020-01-01 | 2020-03-01 | 241d |  |  |  |  | 853 | 853 Refurbishment - Installation |
| 129 | 2.12.2 | **bldg 195** |  | 5d | 2016-11-09 | 2016-11-15 |  | 2016-11-09 | 2016-11-15 | 5d | 2016-11-09 | 2016-11-15 | 1132d |  |  |  |  | 195 | 195 Refurbishment |
| 130 | 2.12.2.1 | cabling |  | 1w | 2016-11-09 | 2016-11-15 |  | 2016-11-09 | 2016-11-15 | 1w | 2016-11-09 | 2016-11-15 | 1132d |  | start no earlier than 2016-11-09 |  |  | 195 | 195 Refurbishment - Installation |
| 131 | 2.12.2.2 | install fixtures and connections |  | 1w | 2016-11-09 | 2016-11-15 |  | 2016-11-09 | 2016-11-15 | 1w | 2016-11-09 | 2016-11-15 | 1132d |  | start no earlier than 2016-11-09 |  |  | 195 | 195 Refurbishment - Installation |
| 132 | 2.13 | **WP13: target mobile shielding curtain** |  | 187d? | 2019-03-14 | 2019-12-02 | 108 | 2019-01-16 | 2019-01-25 | 7d? | 2019-03-14 | 2019-12-01 | 187d | 0d |  | Jean-Louis Grenard | 1496h | 853 | 853 Refurbishment |
| 133 | 2.13.1 | dépose motorisation |  | 1d? | 2019-03-14 | 2019-03-14 |  | 2019-01-16 | 2019-01-17 | 1d? | 2019-03-14 | 2019-03-14 | 426d | 0d |  |  |  | 853 | 853 Refurbishment |
| 134 | 2.13.2 | nettoyage |  | 1d? | 2019-03-15 | 2019-03-15 | 133 | 2019-01-17 | 2019-01-18 | 1d? | 2019-03-15 | 2019-03-15 | 426d | 0d |  |  |  | 853 | 853 Refurbishment |
| 135 | 2.13.3 | montage motorisation |  | 1d? | 2019-11-01 | 2019-11-01 | 82 | 2019-01-24 | 2019-01-25 | 1d? | 2019-11-01 | 2019-11-01 | 261d |  |  |  |  | 853 | 853 Refurbishment - Installation |
| 136 | 2.13.4 | Installation of renovated shielding curtain sys | milestone | 0d | 2019-12-02 | 2019-12-02 |  |  |  |  | 2019-12-01 | 2019-12-01 | 0d |  | must start on 2019-12-02 |  |  | 853 | 853 Refurbishment - Installation |

| ID | WBS | Task | Type | Duration | Start | Finish | Predecessors | Baseline start | Baseline finish | Baseline duration | Baseline 1 start | Baseline 1 finish | Total slack | Free slack | Constraint | Resources | Work | Text4 | Text2 |
| --- | --- | --- | --- | --- | --- | --- | --- | --- | --- | --- | --- | --- | --- | --- | --- | --- | --- | --- | --- |
| 137 | 2.14 | **Other maintenance work** |  | 674d | 2016-11-09 | 2019-06-21 |  | 2016-11-29 | 2016-12-01 | 3d | 2016-11-29 | 2019-08-31 | 333d |  |  |  | 120h | Other |  |
| 138 | 2.14.1 | ventilation |  | 3d | 2016-11-09 | 2016-11-11 |  | 2016-11-29 | 2016-12-01 | 3d | 2016-11-29 | 2016-12-01 | 1134d |  | start no earlier than 2016-11-09 |  |  | Other |  |
| 139 | 2.14.2 | RP |  | 2d | 2016-11-09 | 2016-11-10 |  | 2016-11-29 | 2016-11-30 | 2d | 2016-11-29 | 2016-11-30 | 1135d |  | start no earlier than 2016-11-09 |  |  | Other | 853 |
| 140 | 2.14.3 | Pillar pre-study done | milestone, manual | 0d | 2018-03-02 | 2018-03-02 | 62FS-50d |  |  |  |  |  |  |  |  | Raul Fernandez Ortega |  |  |  |
| 141 | 2.14.4 | Pillar removal and installation reinforcement |  | 15d | 2019-06-03 | 2019-06-21 | 85SF-6d | 2016-11-29 | 2016-11-29 | 1d | 2019-08-20 | 2019-08-31 | 463d |  | start no earlier than 2019-06-03 | Alejandro Martinez Selles | 120h | 853 Refurbishment | 853 |
| 142 | 3 | **LS2 AD Hall** |  | 620d? | 2018-11-12 | 2021-03-26 |  |  |  |  |  |  | 3d |  |  |  | 120h |  |  |
| 143 | 3.1 | **Experimental areas** |  | 1d? | 2018-11-12 | 2018-11-12 |  |  |  |  |  |  | 622d |  |  |  |  |  |  |
| 144 | 3.1.1 | **ALPHA** |  | 1d? | 2018-11-12 | 2018-11-12 |  |  |  |  |  |  | 622d |  |  |  |  |  |  |
| 145 | 3.1.1.1 | <New Task> |  | 1d? | 2018-11-12 | 2018-11-12 |  |  |  |  |  |  | 622d |  |  |  |  |  |  |
| 146 | 3.1.2 | **ATRAP** |  | 1d? | 2018-11-12 | 2018-11-12 |  |  |  |  |  |  | 622d |  |  |  |  |  |  |
| 147 | 3.1.2.1 | <New Task> |  | 1d? | 2018-11-12 | 2018-11-12 |  |  |  |  |  |  | 622d |  | start no earlier than 2018-11-12 |  |  |  |  |
| 148 | 3.1.3 | **ASACUSA** |  | 1d? | 2018-11-12 | 2018-11-12 |  |  |  |  |  |  | 622d |  |  |  |  |  |  |
| 149 | 3.1.3.1 | <New Task> |  | 1d? | 2018-11-12 | 2018-11-12 |  |  |  |  |  |  | 622d |  | start no earlier than 2018-11-12 |  |  |  |  |
| 150 | 3.1.4 | **AEGIS** |  | 1d? | 2018-11-12 | 2018-11-12 |  |  |  |  |  |  | 622d |  |  |  |  |  |  |
| 151 | 3.1.4.1 | <New Task> |  | 1d? | 2018-11-12 | 2018-11-12 |  |  |  |  |  |  | 622d |  | start no earlier than 2018-11-12 |  |  |  |  |
| 152 | 3.1.5 | **BASE** |  | 1d? | 2018-11-12 | 2018-11-12 |  |  |  |  |  |  | 622d |  |  |  |  |  |  |
| 153 | 3.1.5.1 | <New Task> |  | 1d? | 2018-11-12 | 2018-11-12 |  |  |  |  |  |  | 622d |  | start no earlier than 2018-11-12 |  |  |  |  |
| 154 | 3.1.6 | **Gbar** |  | 1d? | 2018-11-12 | 2018-11-12 |  |  |  |  |  |  | 622d |  |  |  |  |  |  |
| 155 | 3.1.6.1 | <New Task> |  | 1d? | 2018-11-12 | 2018-11-12 |  |  |  |  |  |  | 622d |  | start no earlier than 2018-11-12 |  |  |  |  |
| 156 | 3.2 | **AD Ring** |  | 620d? | 2018-11-12 | 2021-03-26 |  |  |  |  |  |  | 3d |  |  |  |  |  |  |
| 157 | 3.2.1 | **MSC** |  | 420d? | 2018-11-12 | 2020-06-19 |  |  |  |  |  |  | 203d |  |  |  |  |  |  |
| 158 | 3.2.1.1 | **Magnet group1** |  | 68d | 2019-08-07 | 2019-11-08 |  |  |  |  |  |  | 301d |  |  |  |  |  |  |
| 159 | 3.2.1.1.1 | Openning shielding |  | 2d | 2019-08-07 | 2019-08-08 | 262 |  |  |  |  |  | 422d | 0d | start no earlier than 2019-08-07 |  |  |  |  |
| 160 | 3.2.1.1.2 | Closing shielding |  | 3d | 2019-08-15 | 2019-08-19 | 174 |  |  |  |  |  | 422d |  |  |  |  |  |  |

Notes:
- 138: Tasks with the pushpin next to them are manually scheduled tasks. Use them when you don't want Project to move the task. Also, you can enter freeform text in the duration, start and finish fields or leave them blank if you don't have all the information yet.
- 141: 1) Responsibilities: Raul responsible for design studies. Alejandro Selles for execution. / 2) Execution of the works during Jun-19 before decontamination. / 3) Raul estimates design studies take 2-3 weeks. Execution 2-3 weeks (depending on the dose/accessibility... etc). coordination/information from CV will be necessary / 4) arc to support shielding of motorized chariots included within studies and executed at the same time. ~ / 5) Romain will provide a brief spec. document to SMB-SE-DOP, including smart team no. and some dimensions specifications: / -Important: To know the desired clearance between the upper part of shielding blocks and the portico. / -This minim clearance is given by the space required by survey and visual inspections of the target&horn from behind the shielding. / -This space is important since it will define the type of reinforcement of the structure. / -Raul suggest to cut a slope in the upper part of the shielding blocks to maximize the visual angle to the target&horn / 6) convenient to have pre-study by SMB-SE-DOP before MarchAbril 2018 since the mechanical systems design shall be finalized by May 2018. Does not need to be very detailed (i.e., execution drawings, are not necessary) but must show that the assumptions made by the mechanical design are feasible, in order to avoid future surprises. / - additional work consisting in drilling a hole in the AD-target area to connect to an adjacent area and provide and optical path to place there the BTV camera

| ID | WBS | Task | Duration | Start | Finish | Predecessors | Total slack | Free slack | Constraint |
| --- | --- | --- | --- | --- | --- | --- | --- | --- | --- |
| 161 | 3.2.1.1.3 | **BHW36** | 46d | 2019-08-09 | 2019-10-11 |  | 299d |  |  |
| 162 | 3.2.1.1.3.1 | Removal magnet | 1d | 2019-08-09 | 2019-08-09 | 159 | 422d | 0d | start no earlier than 2019-08-05 |
| 163 | 3.2.1.1.3.2 | Refurbishment | 20d | 2019-09-02 | 2019-09-27 |  | 283d | 0d | start no earlier than 2019-09-02 |
| 164 | 3.2.1.1.3.3 | Reinstallation of magnet in the ring + closing shielding | 10d | 2019-09-30 | 2019-10-11 | 163 | 383d |  |  |
| 165 | 3.2.1.1.4 | **BHW37** | 45d | 2019-08-12 | 2019-10-11 |  | 298d |  |  |
| 166 | 3.2.1.1.4.1 | Removal magnet | 1d | 2019-08-12 | 2019-08-12 | 162 | 422d | 0d |  |
| 167 | 3.2.1.1.4.2 | Refurbishment | 20d | 2019-09-02 | 2019-09-27 | 163SS | 283d | 0d | start no earlier than 2019-09-02 |
| 168 | 3.2.1.1.4.3 | Reinstallation of magnet in the ring + closing shielding | 10d | 2019-09-30 | 2019-10-11 | 167 | 383d |  |  |
| 169 | 3.2.1.1.5 | **BHN39** | 64d | 2019-08-13 | 2019-11-08 |  | 317d |  |  |
| 170 | 3.2.1.1.5.1 | Removal magnet | 1d | 2019-08-13 | 2019-08-13 | 166 | 422d | 0d |  |
| 171 | 3.2.1.1.5.2 | Refurbishment | 20d | 2019-09-30 | 2019-10-25 | 167 | 283d | 0d |  |
| 172 | 3.2.1.1.5.3 | Reinstallation of magnet in the ring + closing shielding | 10d | 2019-10-28 | 2019-11-08 | 171 | 363d |  |  |
| 173 | 3.2.1.1.6 | **BHN40** | 63d | 2019-08-14 | 2019-11-08 |  | 316d |  |  |
| 174 | 3.2.1.1.6.1 | Removal magnet | 1d | 2019-08-14 | 2019-08-14 | 170 | 422d | 0d |  |
| 175 | 3.2.1.1.6.2 | Refurbishment | 20d | 2019-09-30 | 2019-10-25 | 171SS | 283d | 0d |  |
| 176 | 3.2.1.1.6.3 | Reinstallation of magnet in the ring + closing shielding | 10d | 2019-10-28 | 2019-11-08 | 175 | 363d |  |  |
| 177 | 3.2.1.2 | **Magnet group2** | 340d | 2018-11-12 | 2020-02-28 |  | 283d |  |  |
| 178 | 3.2.1.2.1 | Openning shielding | 2d | 2018-11-12 | 2018-11-13 |  | 603d | 0d | start no earlier than 2018-11-12 |
| 179 | 3.2.1.2.2 | Closing shielding | 3d | 2018-11-16 | 2018-11-20 | 189 | 603d | 0d |  |
| 180 | 3.2.1.2.3 | **BHW20** | 278d | 2018-11-14 | 2019-12-06 |  | 343d |  |  |
| 181 | 3.2.1.2.3.1 | Removal magnet | 1d | 2018-11-14 | 2018-11-14 | 178 | 603d | 0d |  |
| 182 | 3.2.1.2.3.2 | Refurbishment | 20d | 2019-10-28 | 2019-11-22 | 175 | 283d | 0d |  |
| 183 | 3.2.1.2.3.3 | Reinstallation of magnet in the ring + closing shielding | 10d | 2019-11-25 | 2019-12-06 | 182 | 343d |  |  |
| 184 | 3.2.1.2.4 | **BHW21** | 277d | 2018-11-15 | 2019-12-06 |  | 343d |  |  |
| 185 | 3.2.1.2.4.1 | Removal magnet | 1d | 2018-11-15 | 2018-11-15 | 181 | 619d |  |  |
| 186 | 3.2.1.2.4.2 | Refurbishment | 20d | 2019-10-28 | 2019-11-22 | 182SS | 283d | 0d |  |
| 187 | 3.2.1.2.4.3 | Reinstallation of magnet in the ring + closing shielding | 10d | 2019-11-25 | 2019-12-06 | 186 | 343d |  |  |

| ID | WBS | Task | Duration | Start | Finish | Predecessors | Total slack | Free slack | Constraint |
| --- | --- | --- | --- | --- | --- | --- | --- | --- | --- |
| 188 | 3.2.1.2.5 | **BHN18** | 337d | 2018-11-15 | 2020-02-28 |  | 283d |  |  |
| 189 | 3.2.1.2.5.1 | Removal magnet | 1d | 2018-11-15 | 2018-11-15 | 181 | 603d | 0d |  |
| 190 | 3.2.1.2.5.2 | Refurbishment | 20d | 2020-01-20 | 2020-02-14 | 265 | 283d | 0d |  |
| 191 | 3.2.1.2.5.3 | Reinstallation of magnet in the ring + closing shielding | 10d | 2020-02-17 | 2020-02-28 | 190 | 283d |  |  |
| 192 | 3.2.1.3 | **Magnet group3** | 273d | 2018-11-21 | 2019-12-06 |  | 343d |  |  |
| 193 | 3.2.1.3.1 | Opening shielding | 5d | 2018-11-21 | 2018-11-27 | 179 | 603d | 0d | start no earlier than 2018-11-12 |
| 194 | 3.2.1.3.2 | Closing shielding | 5d | 2018-12-03 | 2018-12-07 | 212 | 603d |  |  |
| 195 | 3.2.1.3.3 | **QDN41** | 228d | 2018-11-28 | 2019-10-11 |  | 383d |  |  |
| 196 | 3.2.1.3.3.1 | Removal magnet | 1d | 2018-11-28 | 2018-11-28 | 193 | 603d | 0d | start no earlier than 2018-11-21 |
| 197 | 3.2.1.3.3.2 | Refurbishment | 20d | 2019-09-02 | 2019-09-27 |  | 343d | 0d | start no earlier than 2019-09-02 |
| 198 | 3.2.1.3.3.3 | Reinstallation of magnet in the ring + closing shielding | 10d | 2019-09-30 | 2019-10-11 | 197 | 383d |  |  |
| 199 | 3.2.1.3.4 | **QFN42** | 227d | 2018-11-29 | 2019-10-11 |  | 383d |  |  |
| 200 | 3.2.1.3.4.1 | Removal magnet | 1d | 2018-11-29 | 2018-11-29 | 196 | 609d |  |  |
| 201 | 3.2.1.3.4.2 | Refurbishment | 20d | 2019-09-02 | 2019-09-27 | 197SS | 343d | 0d | start no earlier than 2019-09-02 |
| 202 | 3.2.1.3.4.3 | Reinstallation of magnet in the ring + closing shielding | 10d | 2019-09-30 | 2019-10-11 | 201 | 383d |  |  |
| 203 | 3.2.1.3.5 | **QDS43** | 247d | 2018-11-29 | 2019-11-08 |  | 363d |  |  |
| 204 | 3.2.1.3.5.1 | Removal magnet | 1d | 2018-11-29 | 2018-11-29 | 196 | 609d |  |  |
| 205 | 3.2.1.3.5.2 | Refurbishment | 20d | 2019-09-30 | 2019-10-25 | 201 | 343d | 0d |  |
| 206 | 3.2.1.3.5.3 | Reinstallation of magnet in the ring + closing shielding | 10d | 2019-10-28 | 2019-11-08 | 205 | 363d |  |  |
| 207 | 3.2.1.3.6 | **QFN44** | 247d | 2018-11-29 | 2019-11-08 |  | 363d |  |  |
| 208 | 3.2.1.3.6.1 | Removal magnet | 1d | 2018-11-29 | 2018-11-29 | 196 | 603d | 0d |  |
| 209 | 3.2.1.3.6.2 | Refurbishment | 20d | 2019-09-30 | 2019-10-25 | 205SS | 343d | 0d |  |
| 210 | 3.2.1.3.6.3 | Reinstallation of magnet in the ring + closing shielding | 10d | 2019-10-28 | 2019-11-08 | 209 | 363d |  |  |
| 211 | 3.2.1.3.7 | **QDN45** | 266d | 2018-11-30 | 2019-12-06 |  | 343d |  |  |
| 212 | 3.2.1.3.7.1 | Removal magnet | 1d | 2018-11-30 | 2018-11-30 | 208 | 603d | 0d |  |
| 213 | 3.2.1.3.7.2 | Refurbishment | 20d | 2019-10-28 | 2019-11-22 | 209 | 343d | 0d |  |
| 214 | 3.2.1.3.7.3 | Reinstallation of magnet in the ring + closing shielding | 10d | 2019-11-25 | 2019-12-06 | 213 | 343d |  |  |

| ID | WBS | Task | Duration | Start | Finish | Predecessors | Total slack | Free slack | Constraint |
| --- | --- | --- | --- | --- | --- | --- | --- | --- | --- |
| 215 | 3.2.1.4 | **Magnet group4** | 264d | 2019-06-18 | 2020-06-19 |  | 203d |  |  |
| 216 | 3.2.1.4.1 | Openning shielding | 5d | 2019-06-18 | 2019-06-24 |  | 438d | 0d | start no earlier than 2019-06-18 |
| 217 | 3.2.1.4.2 | Closing shielding | 5d | 2020-06-15 | 2020-06-19 | 283 | 203d |  |  |
| 218 | 3.2.1.4.3 | **BHN05** | 139d | 2019-06-25 | 2020-01-03 |  | 323d |  |  |
| 219 | 3.2.1.4.3.1 | Removal magnet | 1d | 2019-06-25 | 2019-06-25 | 216 | 438d | 0d |  |
| 220 | 3.2.1.4.3.2 | Refurbishment | 20d | 2019-11-25 | 2019-12-20 | 186 | 283d | 0d |  |
| 221 | 3.2.1.4.3.3 | Reinstallation of magnet in the ring + closing shielding | 10d | 2019-12-23 | 2020-01-03 | 220 | 323d |  |  |
| 222 | 3.2.1.4.4 | **QDN01** | 78d | 2019-06-26 | 2019-10-11 |  | 383d |  |  |
| 223 | 3.2.1.4.4.1 | Removal magnet | 1d | 2019-06-26 | 2019-06-26 | 219 | 456d | 0d | start no earlier than 2019-06-18 |
| 224 | 3.2.1.4.4.2 | Refurbishment | 20d | 2019-09-02 | 2019-09-27 |  | 343d | 0d | start no earlier than 2019-09-02 |
| 225 | 3.2.1.4.4.3 | Reinstallation of magnet in the ring + closing shielding | 10d | 2019-09-30 | 2019-10-11 | 224 | 383d |  |  |
| 226 | 3.2.1.4.5 | **QFN02** | 77d | 2019-06-27 | 2019-10-11 |  | 383d |  |  |
| 227 | 3.2.1.4.5.1 | Removal magnet | 1d | 2019-06-27 | 2019-06-27 | 223 | 456d | 0d |  |
| 228 | 3.2.1.4.5.2 | Refurbishment | 20d | 2019-09-02 | 2019-09-27 | 224SS | 343d | 0d |  |
| 229 | 3.2.1.4.5.3 | Reinstallation of magnet in the ring + closing shielding | 10d | 2019-09-30 | 2019-10-11 | 228 | 383d |  |  |
| 230 | 3.2.1.4.6 | **QDS03** | 96d | 2019-06-28 | 2019-11-08 |  | 363d |  |  |
| 231 | 3.2.1.4.6.1 | Removal magnet | 1d | 2019-06-28 | 2019-06-28 | 227 | 456d | 0d |  |
| 232 | 3.2.1.4.6.2 | Refurbishment | 20d | 2019-09-30 | 2019-10-25 | 228 | 343d | 0d |  |
| 233 | 3.2.1.4.6.3 | Reinstallation of magnet in the ring + closing shielding | 10d | 2019-10-28 | 2019-11-08 | 232 | 363d |  |  |
| 234 | 3.2.1.4.7 | **QFN04** | 95d | 2019-07-01 | 2019-11-08 |  | 363d |  |  |
| 235 | 3.2.1.4.7.1 | Removal magnet | 1d | 2019-07-01 | 2019-07-01 | 231 | 456d | 0d |  |
| 236 | 3.2.1.4.7.2 | Refurbishment | 20d | 2019-09-30 | 2019-10-25 | 232SS | 343d | 0d |  |
| 237 | 3.2.1.4.7.3 | Reinstallation of magnet in the ring + closing shielding | 10d | 2019-10-28 | 2019-11-08 | 236 | 363d |  |  |
| 238 | 3.2.1.4.8 | **QDN05** | 114d | 2019-07-02 | 2019-12-06 |  | 343d |  |  |
| 239 | 3.2.1.4.8.1 | Removal magnet | 1d | 2019-07-02 | 2019-07-02 | 235 | 456d |  |  |
| 240 | 3.2.1.4.8.2 | Refurbishment | 20d | 2019-10-28 | 2019-11-22 | 236 | 343d | 0d |  |
| 241 | 3.2.1.4.8.3 | Reinstallation of magnet in the ring + closing shielding | 10d | 2019-11-25 | 2019-12-06 | 240 | 343d |  |  |

| ID | WBS | Task | Duration | Start | Finish | Predecessors | Total slack | Free slack |
| --- | --- | --- | --- | --- | --- | --- | --- | --- |
| 242 | 3.2.1.5 | **Magnet group5** | 316d? | 2018-11-16 | 2020-01-31 |  | 303d |  |
| 243 | 3.2.1.5.1 | **QDC53** | 276d? | 2018-11-16 | 2019-12-06 |  | 343d |  |
| 244 | 3.2.1.5.1.1 | Openning shielding | 1d? | 2018-11-16 | 2018-11-16 | 189 | 616d | 0d |
| 245 | 3.2.1.5.1.2 | Removal magnet | 1d | 2018-11-19 | 2018-11-19 | 244 | 616d | 0d |
| 246 | 3.2.1.5.1.3 | Closing shielding | 1d? | 2018-11-20 | 2018-11-20 | 245 | 616d |  |
| 247 | 3.2.1.5.1.4 | Refurbishment | 20d | 2019-10-28 | 2019-11-22 | 213SS | 343d | 0d |
| 248 | 3.2.1.5.1.5 | Reinstallation of magnet in the ring + closing shielding | 10d | 2019-11-25 | 2019-12-06 | 247 | 343d |  |
| 249 | 3.2.1.5.2 | **BHW08** | 138d? | 2019-06-26 | 2020-01-03 |  | 323d |  |
| 250 | 3.2.1.5.2.1 | Opening shielding | 2d | 2019-06-26 | 2019-06-27 | 219 | 438d | 0d |
| 251 | 3.2.1.5.2.2 | Removal magnet | 1d? | 2019-06-28 | 2019-06-28 | 250 | 438d | 0d |
| 252 | 3.2.1.5.2.3 | Closing shielding | 3d | 2019-07-01 | 2019-07-03 | 251 | 438d | 0d |
| 253 | 3.2.1.5.2.4 | Refurbishment | 20d | 2019-11-25 | 2019-12-20 | 220SS | 283d | 0d |
| 254 | 3.2.1.5.2.5 | Reinstallation of magnet in the ring + closing shielding | 10d | 2019-12-23 | 2020-01-03 | 253 | 323d |  |
| 255 | 3.2.1.5.3 | **BHN45** | 152d? | 2019-07-04 | 2020-01-31 |  | 303d |  |
| 256 | 3.2.1.5.3.1 | Opening shielding | 2d | 2019-07-04 | 2019-07-05 | 252 | 438d | 0d |
| 257 | 3.2.1.5.3.2 | Removal magnet | 1d? | 2019-07-08 | 2019-07-08 | 256 | 438d | 0d |
| 258 | 3.2.1.5.3.3 | Closing shielding | 3d | 2019-07-09 | 2019-07-11 | 257 | 438d | 0d |
| 259 | 3.2.1.5.3.4 | Refurbishment BHN | 20d | 2019-12-23 | 2020-01-17 | 253 | 283d | 0d |
| 260 | 3.2.1.5.3.5 | Reinstallation of magnet in the ring + closing shielding | 10d | 2020-01-20 | 2020-01-31 | 259 | 303d |  |
| 261 | 3.2.1.5.4 | **BHN51** | 146d? | 2019-07-12 | 2020-01-31 |  | 303d |  |
| 262 | 3.2.1.5.4.1 | Opening shielding | 2d | 2019-07-12 | 2019-07-15 | 258 | 438d | 0d |
| 263 | 3.2.1.5.4.2 | Removal magnet | 1d? | 2019-07-16 | 2019-07-16 | 262 | 443d | 0d |
| 264 | 3.2.1.5.4.3 | Closing shielding | 3d | 2019-07-17 | 2019-07-19 | 263 | 443d |  |
| 265 | 3.2.1.5.4.4 | Refurbishment | 20d | 2019-12-23 | 2020-01-17 | 259SS | 283d | 0d |
| 266 | 3.2.1.5.4.5 | Reinstallation of magnet in the ring + closing shielding | 10d | 2020-01-20 | 2020-01-31 | 265 | 303d |  |

| ID | WBS | Task | Duration | Start | Finish | Predecessors | Total slack | Free slack | Constraint |
| --- | --- | --- | --- | --- | --- | --- | --- | --- | --- |
| 267 | 3.2.2 | **VSC** | 1d? | 2018-11-12 | 2018-11-12 |  | 622d |  |  |
| 268 | 3.2.2.1 | **Consolidation program** | 1d? | 2018-11-12 | 2018-11-12 |  | 622d |  |  |
| 269 | 3.2.2.1.1 | Ion pumps | 1d? | 2018-11-12 | 2018-11-12 |  | 622d |  | start no earlier than 2018-11-12 |
| 270 | 3.2.2.1.2 | Bake-out equipment | 1d? | 2018-11-12 | 2018-11-12 |  | 622d |  | start no earlier than 2018-11-12 |
| 271 | 3.2.2.1.3 | Vacuum chambers | 1d? | 2018-11-12 | 2018-11-12 |  | 622d |  | start no earlier than 2018-11-12 |
| 272 | 3.2.2.2 | **Vacuum activities related to action on AD epuipment** | 1d? | 2018-11-12 | 2018-11-12 |  | 622d |  |  |
| 273 | 3.2.2.2.1 | Ring magnet renovation | 1d? | 2018-11-12 | 2018-11-12 |  | 622d |  | start no earlier than 2018-11-12 |
| 274 | 3.2.2.2.2 | New Electron Cooler | 1d? | 2018-11-12 | 2018-11-12 |  | 622d |  | start no earlier than 2018-11-12 |
| 275 | 3.2.2.2.3 | Stochastic cooling kicker tanks | 1d? | 2018-11-12 | 2018-11-12 |  | 622d |  | start no earlier than 2018-11-12 |
| 276 | 3.2.2.2.4 | Target area windows displacement in TFA line | 1d? | 2018-11-12 | 2018-11-12 |  | 622d |  | start no earlier than 2018-11-12 |
| 277 | 3.2.3 | **New Electron cooler TBC** | 320d? | 2020-01-06 | 2021-03-26 |  | 3d |  |  |
| 278 | 3.2.3.1 | Installation in sector 29 | 320d? | 2020-01-06 | 2021-03-26 |  | 3d |  | finish no earlier than 2021-03-26 |
| 279 | 3.2.4 | **RF** | 270d? | 2019-06-18 | 2020-06-29 |  | 197d |  |  |
| 280 | 3.2.4.1 | **New RF system (DRC02)** | 270d? | 2019-06-18 | 2020-06-29 |  | 197d |  |  |
| 281 | 3.2.4.1.1 | Openning shielding | 5d | 2019-06-18 | 2019-06-24 | 216SS | 441d | 244d | start no earlier than 2018-11-12 |
| 282 | 3.2.4.1.2 | Removal Old Cavity C02 | 5d | 2020-06-01 | 2020-06-05 | 281 | 197d | 0d | start no earlier than 2020-06-01 |
| 283 | 3.2.4.1.3 | Installation of new Cavity C02 | 5d | 2020-06-08 | 2020-06-12 | 282 | 197d | 0d |  |
| 284 | 3.2.4.1.4 | Vacuum connexion | 1d? | 2020-06-15 | 2020-06-15 | 283 | 203d | 0d |  |
| 285 | 3.2.4.1.5 | Alignment (Date TBD) | 1d? | 2020-06-16 | 2020-06-16 | 284 | 203d | 0d |  |
| 286 | 3.2.4.1.6 | Preparation of Bakeout | 1d? | 2020-06-17 | 2020-06-17 | 285 | 203d | 0d |  |
| 287 | 3.2.4.1.7 | Pump down leak check | 1d? | 2020-06-18 | 2020-06-18 | 286 | 203d | 0d |  |
| 288 | 3.2.4.1.8 | Bakeout (Date TBD) | 1d? | 2020-06-19 | 2020-06-19 | 287 | 203d |  |  |
| 289 | 3.2.4.1.9 | Closing shielding | 5d | 2020-06-15 | 2020-06-19 | 283 | 197d | 0d |  |
| 290 | 3.2.4.1.10 | Disconnexion Old Cavity (Date: during 2021 TBD) | 5d | 2020-06-22 | 2020-06-26 | 289 | 197d | 0d | start no earlier than 2020-05-11 |
| 291 | 3.2.4.1.11 | Cabling new Cavity (Date: During 2021 TBD) | 1d? | 2020-06-29 | 2020-06-29 | 283, 290 | 197d |  |  |

| ID | WBS | Task | Duration | Start | Finish | Predecessors | Total slack | Free slack | Constraint | Resources | Work | Text12 | Text2 |
| --- | --- | --- | --- | --- | --- | --- | --- | --- | --- | --- | --- | --- | --- |
| 292 | 3.2.5 | **BCCCA** | 1d? | 2018-12-11 | 2018-12-11 |  | 601d |  |  |  |  |  |  |
| 293 | 3.2.5.1 | Maintenance | 1d? | 2018-12-11 | 2018-12-11 |  | 601d |  | start no earlier than 2018-12-11 |  |  |  |  |
| 294 | 3.3 | **ELENA** | 570d | 2018-11-12 | 2021-01-15 |  | 53d |  |  |  | 120h |  |  |
| 295 | 3.3.1 | **Dismantling of current Transfer lines** | 64d | 2018-11-12 | 2019-02-07 |  | 259d | 0d |  |  | 120h | 2016 |  |
| 296 | 3.3.1.1 | Consignations | 1d | 2018-11-12 | 2018-11-12 |  | 269d | 0d | start no earlier than 2018-11-12 |  |  |  | TE/EPC |
| 297 | 3.3.1.2 | Cable disconnections | 1d | 2018-11-13 | 2018-11-13 | 296 | 269d | 0d |  |  |  | 2016 | Equipment owners |
| 298 | 3.3.1.3 | Flexible cooling pipe removal central part | 1d | 2018-11-14 | 2018-11-14 | 297 | 269d | 0d |  |  |  | 2016 | TE/MSC |
| 299 | 3.3.1.4 | Vacuum disconections central part | 1d | 2018-11-15 | 2018-11-15 | 298 | 269d | 0d |  |  |  |  | TE/VSC |
| 300 | 3.3.1.5 | Dismantling of accessible equipment in the central part (2 shield blocks,6 magnets, 2 GEM) | 2d | 2018-11-16 | 2018-11-19 | 299 | 269d | 0d |  |  |  | 2016 | Equipment owners |
| 301 | 3.3.1.6 | Mechanical supports dismantling central part | 1d | 2018-11-20 | 2018-11-20 | 300 | 269d | 0d |  |  |  |  | EN/MME |
| 302 | 3.3.1.7 | Removal of DE0 access control gate | 1d | 2018-11-21 | 2018-11-21 | 301 | 269d | 0d |  |  |  |  | BE/ICS |
| 303 | 3.3.1.8 | Cable removal of DE0 zone only - not up to the racks | 3w | 2018-11-22 | 2018-12-12 | 302 | 269d | 0d |  |  |  | 2016 | EN/EL |
| 304 | 3.3.1.9 | Flexible cooling pipe removal all remaining | 3d | 2018-12-13 | 2018-12-17 | 303 | 269d | 0d |  |  |  | 2016 | TE/MSC |
| 305 | 3.3.1.10 | **BASE transfer line** | 17d | 2018-12-18 | 2019-01-09 | 304 | 259d | 0d |  |  | 24h | 2016 |  |
| 306 | 3.3.1.10.1 | Vacuum disconections | 2d | 2018-12-18 | 2018-12-19 |  | 269d | 0d |  |  |  |  |  |
| 307 | 3.3.1.10.2 | Equipment dismantling (magnets, GEM, ...) | 3d | 2018-12-20 | 2018-12-24 | 306 | 269d | 10d |  | PR TL | 24h | 2016 | Equipment owners |
| 308 | 3.3.1.10.3 | Mechanical support dismantling | 2d | 2019-01-08 | 2019-01-09 | 307 | 259d | 51d | start no earlier than 2019-01-08 |  |  | 2016 | EN/MME |
| 309 | 3.3.1.11 | **ASACUSA Transfer line** | 9d | 2019-01-10 | 2019-01-22 | 305 | 259d | 0d |  |  | 32h | 2016 |  |
| 310 | 3.3.1.11.1 | Vacuum disconections | 3d | 2019-01-10 | 2019-01-14 |  | 259d | 0d |  |  |  |  |  |
| 311 | 3.3.1.11.2 | Equipment dismantling (magnets, GEM, ...) | 4d | 2019-01-15 | 2019-01-18 | 310 | 259d | 0d |  | PR TL | 32h | 2016 | Equipment owners |
| 312 | 3.3.1.11.3 | Mechanical support dismantling | 2d | 2019-01-21 | 2019-01-22 | 311 | 259d |  |  |  |  | 2016 | EN/MME |
| 313 | 3.3.1.11.4 | RFQD removal | 1w | 2019-01-10 | 2019-01-16 |  | 263d |  |  |  |  |  | BE/RF |
| 314 | 3.3.1.12 | **ATRAP/ALPHA Transfer line** | 12d | 2019-01-23 | 2019-02-07 | 309 | 259d |  |  |  | 64h | 2016 |  |
| 315 | 3.3.1.12.1 | Vacuum disconnections | 2d | 2019-01-23 | 2019-01-24 |  | 259d | 0d |  |  |  |  |  |
| 316 | 3.3.1.12.2 | Equipment dismantling (magnets, GEM, …) | 8d | 2019-01-25 | 2019-02-05 | 315 | 259d | 0d |  | PR TL | 64h | 2016 | Equipment owners + EN/MME |
| 317 | 3.3.1.12.3 | Mechanical supports dismantling | 2d | 2019-02-06 | 2019-02-07 | 316 | 259d |  |  |  |  |  | EN/MME |

Notes:
- 295: Text10: 07/02/2019 - Dismantling of current Transfer lines
- 296: Text10: 12/11/2018 - Consignations
- 297: Text10: 13/11/2018 - Cable disconnections
- 298: Text10: 14/11/2018 - Flexible cooling pipe removal central part
- 299: Text10: 15/11/2018 - Vacuum disconections central part
- 300: Text10: 19/11/2018 - Dismantling of accessible equipment in the central part (2 shield blocks,6 magnets, 2 GEM)
- 301: Text10: 20/11/2018 - Mechanical supports dismantling central part
- 302: Text10: 21/11/2018 - Removal of DE0 access control gate
- 303: Text10: 12/12/2018 - Cable removal of DE0 zone only - not up to the racks
- 304: Text10: 17/12/2018 - Flexible cooling pipe removal all remaining
- 305: Text10: 09/01/2019 - BASE transfer line
- 306: Text10: 19/12/2018 - Vacuum disconections
- 307: Text10: 07/01/2019 - Equipment dismantling (magnets, GEM, ...)
- 308: Text10: 09/01/2019 - Mechanical support dismantling
- 309: Text10: 22/01/2019 - ASACUSA Transfer line
- 310: Text10: 14/01/2019 - Vacuum disconections
- 311: Text10: 18/01/2019 - Equipment dismantling (magnets, GEM, ...)
- 312: Text10: 22/01/2019 - Mechanical support dismantling
- 313: Text10: 16/01/2019 - RFQD removal
- 314: Text10: 07/02/2019 - ATRAP/ALPHA Transfer line
- 315: Text10: 24/01/2019 - Vacuum disconnections
- 316: Text10: 05/02/2019 - Equipment dismantling (magnets, GEM, …)
- 317: Text10: 07/02/2019 - Mechanical supports dismantling

| ID | WBS | Task | Type | Duration | Start | Finish | Predecessors | Total slack | Free slack | Text2 | Text12 | Text5 |
| --- | --- | --- | --- | --- | --- | --- | --- | --- | --- | --- | --- | --- |
| 318 | 3.3.2 | **Infrastructure modifs** |  | 30d | 2019-02-08 | 2019-03-21 | 295 | 259d | 0d |  |  |  |
| 319 | 3.3.2.1 | Remove stochastic cooling equipment |  | 1w | 2019-02-08 | 2019-02-14 |  | 284d |  | BE/RF |  |  |
| 320 | 3.3.2.2 | Removal of big piping on AD wall |  | 1w | 2019-02-08 | 2019-02-14 |  | 259d | 0d | EN/CV |  |  |
| 321 | 3.3.2.3 | Removal of cable trays on AD wall and BASE wall |  | 1w | 2019-02-15 | 2019-02-21 | 320 | 259d | 0d | EN/EL |  |  |
| 322 | 3.3.2.4 | Shielding modification around BASE TL |  | 4d | 2019-02-22 | 2019-02-27 | 321 | 270d | 1d | EN/HE | 2016 |  |
| 323 | 3.3.2.5 | AD Shielding roof and wall opening |  | 1w | 2019-02-22 | 2019-02-28 | 321 | 259d | 0d | EN/HE |  |  |
| 324 | 3.3.2.6 | Long concrete beam cut |  | 3d | 2019-03-01 | 2019-03-05 | 323 | 271d |  | SMB |  |  |
| 325 | 3.3.2.7 | Drilling in the shielding block for ASACUSA TL |  | 1w | 2019-03-01 | 2019-03-07 | 322, 323 | 269d | 10d | SMB | 2016 |  |
| 326 | 3.3.2.8 | AD DE0 equipment dismantling (vacuum, 4 magnets, 1 GEM) |  | 4d | 2019-03-01 | 2019-03-06 | 323 | 259d | 0d | Equipment owners |  |  |
| 327 | 3.3.2.9 | AD DEO supports dismantling |  | 1d | 2019-03-07 | 2019-03-07 | 326 | 259d | 0d |  |  |  |
| 328 | 3.3.2.10 | New AD shielding wall re-install |  | 1w | 2019-03-08 | 2019-03-14 | 327 | 259d | 0d | EN/HE |  |  |
| 329 | 3.3.2.11 | Re-install sochastic cooling equipment |  | 1w | 2019-03-15 | 2019-03-21 | 328 | 259d |  | BE/RF |  |  |
| 330 | 3.3.2.12 | New demi water piping install |  | 1w | 2019-03-15 | 2019-03-21 | 328 | 259d |  | EN/CV |  |  |
| 331 | 3.3.3 | **Installation of the Transfer lines and services** |  | 80d | 2019-03-22 | 2019-07-11 | 295, 318 | 259d |  |  | 2016 |  |
| 332 | 3.3.3.1 | Survey Marking (including new network and holes marking) |  | 2w | 2019-03-22 | 2019-04-04 | 308, 325 | 413d | 0d | EN/MEF | 2016 |  |
| 333 | 3.3.3.2 | Drilling for the mechanical support |  | 2w | 2019-04-05 | 2019-04-18 | 332 | 413d | 0d | EN/MME | 2016 |  |
| 334 | 3.3.3.3 | Installation of the new mechanical support |  | 3w | 2019-04-19 | 2019-05-09 | 333 | 413d | 0d | EN/MME | 2016 |  |
| 335 | 3.3.3.4 | Cabling work can technically start | milestone | 0d | 2019-05-09 | 2019-05-09 | 334 | 494d |  |  |  |  |
| 336 | 3.3.3.5 | **Cabling campaign** |  | 60d | 2019-03-22 | 2019-06-13 |  | 259d | 9d | EN/EL | 2016 | To be studied |
| 337 | 3.3.3.5.1 | Installation of cable trays |  | 1w | 2019-03-22 | 2019-03-28 |  | 259d | 0d | EN/EL | 2016 | To be studied |
| 338 | 3.3.3.5.2 | Installation of AC: power sockets for bake-out |  | 3w | 2019-03-29 | 2019-04-18 | 337 | 259d | 0d | EN/EL | 2016 | To be studied |
| 339 | 3.3.3.5.3 | Installation of control cables for vacuum |  | 2w | 2019-04-19 | 2019-05-02 | 337, 338 | 259d | 0d |  |  |  |
| 340 | 3.3.3.5.4 | Installation of HV cables for electrostatic elements |  | 3w | 2019-05-03 | 2019-05-23 | 339 | 259d | 0d |  |  |  |
| 341 | 3.3.3.5.5 | Installation of control cables for electrostatic elements + WIC |  | 3w | 2019-05-24 | 2019-06-13 | 340 | 259d |  |  |  |  |
| 342 | 3.3.3.5.6 | Optical fibres and boxes plus patch cords installation |  | 2w | 2019-03-29 | 2019-04-11 | 337 | 304d |  |  |  |  |
| 343 | 3.3.3.6 | Installation of electrostatics element + SEM |  | 3w | 2019-05-10 | 2019-05-30 | 334 | 413d | 0d | TE/VSC | 2016 |  |
| 344 | 3.3.3.7 | Alignement of electrostatic elements by the survey |  | 2w | 2019-05-31 | 2019-06-13 | 343 | 413d | 0d | EN/MEF | 2016 |  |
| 345 | 3.3.3.8 | Electrical connection of electrostatic elements |  | 2w | 2019-06-14 | 2019-06-27 | 344 | 449d | 0d | TE/ABT |  |  |
| 346 | 3.3.3.9 | Electrical connection of SEM |  | 2w | 2019-06-28 | 2019-07-11 | 345 | 449d |  | EP/UAD |  |  |

Notes:
- 318: Text10: 21/03/2019 - Infrastructure modifs
- 319: Text10: 14/02/2019 - Remove stochastic cooling equipment
- 320: Text10: 14/02/2019 - Removal of big piping on AD wall
- 321: Text10: 21/02/2019 - Removal of cable trays on AD wall and BASE wall
- 322: Text10: 27/02/2019 - Shielding modification around BASE TL
- 323: Text10: 28/02/2019 - AD Shielding roof and wall opening
- 324: Text10: 05/03/2019 - Long concrete beam cut
- 325: Text10: 07/03/2019 - Drilling in the shielding block for ASACUSA TL
- 326: Text10: 06/03/2019 - AD DE0 equipment dismantling (vacuum, 4 magnets, 1 GEM)
- 327: Text10: 07/03/2019 - AD DEO supports dismantling
- 328: Text10: 14/03/2019 - New AD shielding wall re-install
- 329: Text10: 21/03/2019 - Re-install sochastic cooling equipment
- 330: Text10: 21/03/2019 - New demi water piping install
- 331: Text10: 27/03/2020 - Installation of the Transfer lines and services
- 332: Text10: 04/04/2019 - Survey Marking (including new network and holes marking)
- 333: Text10: 18/04/2019 - Drilling for the mechanical support
- 334: Text10: 09/05/2019 - Installation of the new mechanical support
- 335: Text10: 09/05/2019 - Cabling work can technically start
- 336: Text10: 27/03/2020 - Cabling campaign
- 337: Text10: 10/01/2020 - Installation of cable trays
- 338: Text10: 31/01/2020 - Installation of AC: power sockets for bake-out
- 339: Text10: 14/02/2020 - Installation of control cables for vacuum
- 340: Text10: 06/03/2020 - Installation of HV cables for electrostatic elements
- 341: Text10: 27/03/2020 - Installation of control cables for electrostatic elements + WIC
- 342: Text10: 24/01/2020 - Optical fibres and boxes plus patch cords installation
- 343: Text10: 30/05/2019 - Installation of electrostatics element + SEM
- 344: Text10: 13/06/2019 - Alignement of electrostatic elements by the survey
- 345: Text10: 27/06/2019 - Electrical connection of electrostatic elements
- 346: Text10: 11/07/2019 - Electrical connection of SEM

| ID | WBS | Task | Duration | Start | Finish | Predecessors | Total slack | Free slack | Text12 | Text2 |
| --- | --- | --- | --- | --- | --- | --- | --- | --- | --- | --- |
| 347 | 3.3.4 | **Vacuum work** | 56d | 2019-06-14 | 2019-08-30 |  | 413d |  |  |  |
| 348 | 3.3.4.1 | **BASE: LNE07 and the end of LNE00** | 26d | 2019-06-14 | 2019-07-19 |  | 413d |  | 2016 |  |
| 349 | 3.3.4.1.1 | Vacuum connection + installation of vacuum equipment | 4d | 2019-06-14 | 2019-06-19 | 344 | 413d | 0d | 2016 | TE/VSC |
| 350 | 3.3.4.1.2 | **Bake-out Vac sector H (LNE00-LNE01)** | 17d | 2019-06-20 | 2019-07-12 |  | 413d |  | 2016 | TE/VSC |
| 351 | 3.3.4.1.2.1 | Bake-out preparation | 5d | 2019-06-20 | 2019-06-26 | 349 | 413d | 0d | 2016 | TE/VSC |
| 352 | 3.3.4.1.2.2 | Bake-out | 2w | 2019-06-27 | 2019-07-10 | 336, 351 | 418d | 0d | 2016 | TE/VSC |
| 353 | 3.3.4.1.2.3 | Decablage | 2d | 2019-07-11 | 2019-07-12 | 352 | 446d | 3d | 2016 | TE/VSC |
| 354 | 3.3.4.1.3 | **Bake-out Vac sector O (BASE)** | 17d | 2019-06-27 | 2019-07-19 |  | 413d |  | 2016 | TE/VSC |
| 355 | 3.3.4.1.3.1 | Bake-out preparation | 5d | 2019-06-27 | 2019-07-03 | 351 | 413d | 0d | 2016 | TE/VSC |
| 356 | 3.3.4.1.3.2 | Bake-out | 2w | 2019-07-04 | 2019-07-17 | 336, 355 | 413d | 0d | 2016 | TE/VSC |
| 357 | 3.3.4.1.3.3 | Decablage | 2d | 2019-07-18 | 2019-07-19 | 353, 356 | 443d |  | 2016 | TE/VSC |
| 358 | 3.3.4.2 | **ASACUSA: first half of LNE01, LNE06 and LNE05** | 34d | 2019-06-20 | 2019-08-06 |  | 415.5d |  | 2016 | TE/VSC |
| 359 | 3.3.4.2.1 | Vacuum connection + installation of vacuum equipment | 1.5w | 2019-06-20 | 2019-07-01 | 344, 349 | 415.5d | 0d | 2016 | TE/VSC |
| 360 | 3.3.4.2.2 | **Bake-out Vac sector M (LNE06)** | 22d | 2019-07-04 | 2019-08-02 |  | 413d |  | 2016 | TE/VSC |
| 361 | 3.3.4.2.2.1 | Bake-out preparation | 5d | 2019-07-04 | 2019-07-10 | 355, 359 | 413d | 0d | 2016 | TE/VSC |
| 362 | 3.3.4.2.2.2 | Bake-out | 2w | 2019-07-18 | 2019-07-31 | 352, 356, 361 | 431d | 0d | 2016 | TE/VSC |
| 363 | 3.3.4.2.2.3 | Decablage | 2d | 2019-08-01 | 2019-08-02 | 362 | 431d | 0d | 2016 | TE/VSC |
| 364 | 3.3.4.2.3 | **Bake-out Vac sector N (LNE05)** | 19d | 2019-07-11 | 2019-08-06 |  | 413d |  | 2016 | TE/VSC |
| 365 | 3.3.4.2.3.1 | Bake-out preparation | 5d | 2019-07-11 | 2019-07-17 | 361 | 413d | 0d | 2016 | TE/VSC |
| 366 | 3.3.4.2.3.2 | Bake-out | 2w | 2019-07-18 | 2019-07-31 | 352, 356, 365 | 413d | 0d | 2016 | TE/VSC |
| 367 | 3.3.4.2.3.3 | Decablage | 2d | 2019-08-05 | 2019-08-06 | 363, 366 | 431d |  | 2016 | TE/VSC |
| 368 | 3.3.4.3 | **ALPHA/ATRAP Second half of LNE01, LNE03 and LNE04** | 44.5d | 2019-07-01 | 2019-08-30 |  | 413d |  | 2016 |  |
| 369 | 3.3.4.3.1 | Vacuum connection + installation of vacuum equipment | 1.5w | 2019-07-01 | 2019-07-10 | 349, 359 | 450d |  | 2016 | TE/VSC |
| 370 | 3.3.4.3.2 | **Bake-out Vac sector K (LNE03)** | 22d | 2019-07-18 | 2019-08-16 |  | 421d |  | 2016 | TE/VSC |
| 371 | 3.3.4.3.2.1 | Bake-out preparation | 5d | 2019-07-18 | 2019-07-24 | 365 | 426d | 0d | 2016 | TE/VSC |
| 372 | 3.3.4.3.2.2 | Bake-out | 2w | 2019-08-01 | 2019-08-14 | 366, 371 | 421d | 0d | 2016 | TE/VSC |
| 373 | 3.3.4.3.2.3 | Decablage | 2d | 2019-08-15 | 2019-08-16 | 372 | 421d | 0d | 2016 | TE/VSC |

Notes:
- 347: Text10: 26/05/2020 - Vacuum work
- 348: Text10: 16/04/2020 - BASE: LNE07 and the end of LNE00
- 349: Text10: 19/06/2019 - Vacuum connection + installation of vacuum equipment
- 350: Text10: 14/04/2020 - Bake-out Vac sector H (LNE00-LNE01)
- 351: Text10: 26/06/2019 - Bake-out preparation
- 352: Text10: 10/04/2020 - Bake-out
- 353: Text10: 14/04/2020 - Decablage
- 354: Text10: 16/04/2020 - Bake-out Vac sector O (BASE)
- 355: Text10: 03/07/2019 - Bake-out preparation
- 356: Text10: 10/04/2020 - Bake-out
- 357: Text10: 16/04/2020 - Decablage
- 358: Text10: 30/04/2020 - ASACUSA: first half of LNE01, LNE06 and LNE05
- 359: Text10: 01/07/2019 - Vacuum connection + installation of vacuum equipment
- 360: Text10: 28/04/2020 - Bake-out Vac sector M (LNE06)
- 361: Text10: 10/07/2019 - Bake-out preparation
- 362: Text10: 24/04/2020 - Bake-out
- 363: Text10: 28/04/2020 - Decablage
- 364: Text10: 30/04/2020 - Bake-out Vac sector N (LNE05)
- 365: Text10: 17/07/2019 - Bake-out preparation
- 366: Text10: 24/04/2020 - Bake-out
- 367: Text10: 30/04/2020 - Decablage
- 368: Text10: 26/05/2020 - ALPHA/ATRAP Second half of LNE01, LNE03 and LNE04
- 369: Text10: 10/07/2019 - Vacuum connection + installation of vacuum equipment
- 370: Text10: 12/05/2020 - Bake-out Vac sector K (LNE03)
- 371: Text10: 24/07/2019 - Bake-out preparation
- 372: Text10: 08/05/2020 - Bake-out
- 373: Text10: 12/05/2020 - Decablage

| ID | WBS | Task | Duration | Start | Finish | Predecessors | Total slack | Free slack | Constraint | Text2 | Text12 |
| --- | --- | --- | --- | --- | --- | --- | --- | --- | --- | --- | --- |
| 374 | 3.3.4.3.3 | **Bake-out Vac sector L (LNE04)** | 19d | 2019-07-25 | 2019-08-20 |  | 418d |  |  | TE/VSC | 2016 |
| 375 | 3.3.4.3.3.1 | Bake-out preparation | 5d | 2019-07-25 | 2019-07-31 | 371 | 430d | 0d |  | TE/VSC | 2016 |
| 376 | 3.3.4.3.3.2 | Bake-out | 2w | 2019-08-01 | 2019-08-14 | 366 | 413d | 0d |  | TE/VSC | 2016 |
| 377 | 3.3.4.3.3.3 | Decablage | 2d | 2019-08-19 | 2019-08-20 | 373, 376 | 421d |  |  | TE/VSC | 2016 |
| 378 | 3.3.4.3.4 | **Bake-out Vac sector I (LNE02)** | 22d | 2019-08-01 | 2019-08-30 |  | 413d |  |  | TE/VSC | 2016 |
| 379 | 3.3.4.3.4.1 | Bake-out preparation | 5d | 2019-08-01 | 2019-08-07 | 375 | 430d |  |  | TE/VSC | 2016 |
| 380 | 3.3.4.3.4.2 | Bake-out | 2w | 2019-08-15 | 2019-08-28 | 376 | 413d | 0d |  | TE/VSC | 2016 |
| 381 | 3.3.4.3.4.3 | Decablage | 2d | 2019-08-29 | 2019-08-30 | 380 | 413d |  |  | TE/VSC | 2016 |
| 382 | 3.3.5 | Commissioning ELENA TL's | 42w | 2020-03-30 | 2021-01-15 | 336 | 53d |  | start no earlier than 2020-03-30 |  | 2016 |
| 383 | 3.3.6 | Removal of all cables, including outside AD hall | 4w | 2020-11-02 | 2020-11-27 |  | 88d |  | start no earlier than 2020-11-02 |  |  |
| 384 | 3.4 | **Other** | 427d? | 2018-11-12 | 2020-06-30 |  | 196d |  |  |  |  |
| 385 | 3.4.1 | **Infrastructure** | 216d? | 2019-09-03 | 2020-06-30 |  | 196d |  |  |  |  |
| 386 | 3.4.1.1 | **CV** | 195d? | 2019-09-03 | 2020-06-01 |  | 217d |  |  |  |  |
| 387 | 3.4.1.1.1 | Refurbishment of cooling station | 195d? | 2019-09-03 | 2020-06-01 |  | 217d |  | finish no earlier than 2020-06-01 |  |  |
| 388 | 3.4.1.2 | **Cryo** | 65d? | 2020-04-01 | 2020-06-30 |  | 196d |  |  |  |  |
| 389 | 3.4.1.2.1 | New cryo distribution to experiments. TBC | 65d? | 2020-04-01 | 2020-06-30 |  | 196d |  | finish no earlier than 2020-06-30 |  |  |
| 390 | 3.4.2 | **Power Converter** | 1d? | 2018-11-12 | 2018-11-12 |  | 622d |  |  |  |  |
| 391 | 3.4.2.1 | **TE ABT Magnetic Horn Pulser** | 1d? | 2018-11-12 | 2018-11-12 |  | 622d |  |  |  |  |
| 392 | 3.4.2.1.1 | Complete renewal of old system employing mercury switches | 1d? | 2018-11-12 | 2018-11-12 |  | 622d |  | start no earlier than 2018-11-12 |  |  |
| 393 | 3.4.2.1.2 | b.195 | 1d? | 2018-11-12 | 2018-11-12 |  | 622d |  | start no earlier than 2018-11-12 |  |  |
| 394 | 3.4.2.2 | **TE-EPC Pulsed Power converters for injection line magnets** | 1d? | 2018-11-12 | 2018-11-12 |  | 622d |  |  |  |  |
| 395 | 3.4.2.2.1 | New Capacitor discharge designe, MegaDisCap/MarxDisCap | 1d? | 2018-11-12 | 2018-11-12 |  | 622d |  | start no earlier than 2018-11-12 |  |  |
| 396 | 3.4.2.2.2 | 12 units to be replaced | 1d? | 2018-11-12 | 2018-11-12 |  | 622d |  | start no earlier than 2018-11-12 |  |  |
| 397 | 3.4.2.2.3 | Assuming successful construction of new permanent magnets in target area | 1d? | 2018-11-12 | 2018-11-12 |  | 622d |  | start no earlier than 2018-11-12 |  |  |
| 398 | 3.4.2.2.4 | b.370/b.193 | 1d? | 2018-11-12 | 2018-11-12 |  | 622d |  | start no earlier than 2018-11-12 |  |  |

Notes:
- 374: Text10: 14/05/2020 - Bake-out Vac sector L (LNE04)
- 375: Text10: 31/07/2019 - Bake-out preparation
- 376: Text10: 08/05/2020 - Bake-out
- 377: Text10: 14/05/2020 - Decablage
- 378: Text10: 26/05/2020 - Bake-out Vac sector I (LNE02)
- 379: Text10: 07/08/2019 - Bake-out preparation
- 380: Text10: 22/05/2020 - Bake-out
- 381: Text10: 26/05/2020 - Decablage
- 382: Text10: 23/03/2021 - Commissioning ELENA TL's
- 383: Text10: 27/11/2020 - Removal of all cables, including outside AD hall
